# 3GPP_Release-2000

Schedule from MS Project, 2000-01-03 to 2008-02-15, A marks actual dates.

## Calendars

- Standard: Mon-Fri 08:00-12:00, 13:00-17:00; Sat-Sun off.

## Resources

| Resource |
| --- |
| NP |
| N1 |
| N2 |
| N3 |
| N4 |
| N5 |
| TP |
| T1 |
| T2 |
| T3 |
| RP |
| R1 |
| R2 |
| R3 |
| R4 |
| SP |
| S1 |
| S2 |
| S3 |
| S4 |
| S5 |
| PCG |
| GP |
| No |
| CN4 |
| ? |
| WG G2 |
| G2 |
| G1 |
| G4 |
| G3 |
| All |
| Generic |
| MLST |
| G5 |
| S3; G2 |
| WG T2 |
| GP;G1 |
| G4;G5 |
| OMA |
| GP-G2 |
| Yes |
| GP; |
| N4; |
| GP; N1 |
| CT5 |
| C5 |
| C1 |
| C4 |
| C3 |
| C6 |
| G1; |
| 4 |
| ct |
| c;s;r |
| CT;RAN;SA |
| G2, |
| G1; G3 |
| CT6 |
| CT1 |
| CT1, CT3, CT4 |
| C1, C3, C4 |
| CP |

## Schedule

| ID | WBS | Task | Type | Duration | Start | Finish | Complete | Remaining | Baseline start | Baseline finish | Baseline duration | Total slack | Constraint | Resources | Work | Actual work | Text9 | Text6 | Text1 | Text4 | Text5 | Text7 | Text8 | Text12 |
| --- | --- | --- | --- | --- | --- | --- | --- | --- | --- | --- | --- | --- | --- | --- | --- | --- | --- | --- | --- | --- | --- | --- | --- | --- |
| 1 | 1 | VERSION 2007 April 3rd |  | 1d | 2000-01-03 | 2000-01-03 |  |  | 2000-01-03 | 2000-01-03 | 1d | 2119d |  |  |  |  | 2044 |  |  |  |  |  |  |  |
| 2 | 2 | "CTRL + a" to display all the 3GPP fields |  | 1d | 2000-01-03 | 2000-01-03 |  |  | 2000-01-03 | 2000-01-03 | 1d | 2119d |  |  |  |  | 1462 |  |  |  |  |  |  |  |
| 3 | 3 | Content of Rel-7 (frozen) |  | 1d | 2000-01-03 | 2000-01-03 |  |  | 2000-01-03 | 2000-01-03 | 1d | 2119d |  |  |  |  | 2058 |  |  |  |  |  |  |  |
| 5 | 4 | Rel-7 Features |  | 1d? | 2000-01-03 | 2000-01-03 |  |  | 2000-01-03 | 2000-01-03 | 1d? | 2119d |  | CT;RAN;SA | 8h |  |  | Rel-7 |  |  |  |  |  |  |
| 6 | 8.5 | **Multiple Input Multiple Output antennas (MIMO)** |  | 1102d? | 2003-03-14 A | 2007-06-04 | 98% | 19.52d? | 2003-03-14 | 2007-06-04 | 1102d? | 184d |  | R1 | 39072h | 31819.2h | 2468 | Rel-7 | MIMO | Howard Huang, Alcatel-Lucent | hchuang@Alcatel-Lucent.com | TSG | Claude |  |
| 7 | 5.1 | MIMO - Physical layer |  | 915d? | 2003-09-12 A | 2007-03-15 A | 100% |  | 2003-09-12 | 2007-03-15 | 915d? |  | finish no earlier than 2007-03-15 | R1 | 7320h | 7320h |  | Rel-7 | MIMO-Phys | Howard Huang, Alcatel-Lucent | hchuang@Alcatel-Lucent.com | TSG | MCC_RAN |  |
| 8 | 5.2 | MIMO - Layer 2,3 aspects |  | 915d? | 2003-09-12 A | 2007-03-15 A | 100% |  | 2003-09-12 | 2007-03-15 | 915d? |  | finish no earlier than 2007-03-15 | R2 | 7320h | 7320h |  | Rel-7 | MIMO-L23 | Howard Huang, Alcatel-Lucent | hchuang@Alcatel-Lucent.com | TSG | MCC_RAN |  |
| 9 | 5.3 | MIMO - Iub/Iur Protocol Aspects |  | 1045d? | 2003-03-14 A | 2007-03-15 A | 100% |  | 2003-03-14 | 2007-03-15 | 1045d? |  | finish no earlier than 2007-03-15 | R3 | 8360h | 8360h |  | Rel-7 | MIMO-IurIub | Howard Huang, Alcatel-Lucent | hchuang@Alcatel-Lucent.com | TSG | MCC_RAN |  |
| 10 | 5.4 | MIMO - RF Radio Transmission/Reception, System Performance Requirements and Conformance Testing |  | 907d? | 2003-12-12 A | 2007-06-04 | 93% | 67d? | 2003-12-12 | 2007-06-04 | 907d? | 184d | finish no earlier than 2007-06-04 | R4 | 7256h | 6720h |  | Rel-7 | MIMO-RF | Man Hung Ng, Alcatel-Lucent | ngm@Alcatel-Lucent.com | TSG | MCC_RAN |  |
| 11 | 6 | **Rel-7 Improvements of the Radio Interface** |  | 718d? | 2004-09-15 A | 2007-06-15 | 95% | 35.5d? | 2004-09-15 | 2007-06-15 | 718d? | 175d |  | RP | 32144h | 25432.4h |  | Rel-7 | RInImp |  |  |  | Claude |  |
| 12 | 6.1 | Extended UMTS 1.7/2.1 GHz |  | 198d? | 2006-03-15 A | 2006-12-15 A | 100% |  | 2006-03-15 | 2006-12-15 | 198d? |  | finish no earlier than 2006-12-15 | R4 | 1584h | 1584h |  | Rel-7 | RInImp-UMTS1721Ext | Johan Sköld | johan.skold@ericsson.com |  | MCC_RAN |  |
| 13 | 6.2 | UMTS 2.6 GHz 7.68 MHz TDD |  | 67d? | 2006-06-15 A | 2006-09-15 A | 100% |  | 2006-06-15 | 2006-09-15 | 67d? |  | finish no earlier than 2006-09-15 | R4 | 536h | 536h |  | Rel-7 | RInImp-UMTS26VHCRTDD | Shin Horng Wong , IPWireless | shwong@ipwireless.com |  | MCC_RAN |  |
| 14 | 6.3 | UMTS 2.6 GHz |  | 195d? | 2004-09-15 A | 2005-06-14 A | 100% |  | 2004-09-15 | 2005-06-14 | 195d? |  | finish no earlier than 2005-06-14 | R4 | 1560h | 1560h |  | Rel-7 | RInImp-UMTS2600 | Jussi Numminen, Nokia | jussi.numminen@nokia.com | TSG | Claude |  |
| 15 | 6.4 | UMTS 2.6 GHz TDD |  | 261d? | 2004-12-15 A | 2005-12-14 A | 100% |  | 2004-12-15 | 2005-12-14 | 261d? |  | finish no earlier than 2005-12-15 | R4 | 2088h | 2088h |  | Rel-7 | RInImp-UMTS2600TDD | Shin Horng Wong (IPWireless) | shwong@IPWIRELESS.COM | TSG | MCC_RAN |  |
| 16 | 6.5 | UMTS 900 MHz |  | 261d? | 2004-12-15 A | 2005-12-14 A | 100% |  | 2004-12-15 | 2005-12-14 | 261d? |  | finish no earlier than 2005-12-15 | R4 | 2088h | 2088h |  | Rel-7 | RInImp-UMTS900 | Yannick Li (Nortel) | yli@nortelnetworks.com | TSG | MCC_RAN |  |
| 17 | 6.6 | UMTS 1700 MHz |  | 197d? | 2005-03-15 A | 2005-12-14 A | 100% |  | 2005-03-15 | 2005-12-14 | 197d? |  | finish no earlier than 2005-12-15 | R4 | 1576h | 1576h |  | Rel-7 | RInImp-UMTS1700 | Takehiro Nakamura | NTT DoCoMo | TSG | MCC_RAN |  |
| 18 | 6.7 | UE Antenna Performance Evaluation Method and Requirements |  | 644d? | 2004-12-15 A | 2007-06-04 | 93% | 46d? | 2004-12-15 | 2007-06-04 | 644d? | 184d | finish no earlier than 2007-06-04 | R4 | 5152h | 4784h |  | Rel-7 | RInImp-UEAnt | Christian Bergljung (TeliaSonera) | Christian.Bergljung@TeliaSonera.com | TSG | MCC_RAN |  |
| 19 | 6.8 | Improved Performance Requirements for HSDPA UE based on Rx Diversity (type 1) & LMMSE equalizer (type 2) | milestone | 0d? | 2005-03-15 A | 2005-03-15 A | 100% |  | 2005-03-15 | 2005-03-15 | 0d? |  | finish no earlier than 2005-03-15 | R4 |  |  |  | Rel-7 | RInImp-HSPerf-Type3 | Marc Grant | marc.grant@cingular.com | TSG | MCC_RAN |  |
| 20 | 6.9 | **Additional minimum UE performance requirement for non-HSDPA channels based on type 1 enhanced receiver (Rx Diversity)** |  | 327d? | 2005-09-15 A | 2006-12-15 | 99% | 0d? | 2005-09-15 | 2006-12-15 | 327d? | 0d |  | R4 | 7344h | 5500.08h |  | Rel-7 | RInImp-RxDiv | Serge Willenegger | sergew@qualcomm.com |  | MCC_RAN |  |
| 21 | 6.9.1 | Additional minimum UE performance requirement for DL physical channels in support of DCH/HS-DSCH operation based on type 1 enhanced receiver (RX-Diversity) |  | 195d? | 2005-09-15 A | 2006-06-14 A | 100% |  | 2005-09-15 | 2006-06-14 | 195d? |  | finish no earlier than 2006-06-15 | R4 | 1560h | 1560h |  | Rel-7 | RInImp-RxDiv-DCH | Marc Grant | marc.grant@cingular.com | TSG | MCC_RAN |  |
| 22 | 6.9.2 | Additional minimum UE performance requirement for downlink physical channels in support of MTCH and MCCH operation based on type 1 enhanced receiver (Rx-Diversity) |  | 198d? | 2006-03-15 A | 2006-12-15 A | 100% |  | 2006-03-15 | 2006-12-15 | 198d? |  | finish no earlier than 2006-12-15 | R4 | 1584h | 1584h |  | Rel-7 | RInImp-RxDiv-MBMS | Serge Willenegger | sergew@qualcomm.com |  | MCC_RAN |  |
| 23 | 6.9.3 | Additional minimum UE performance requirement for downlink physical channels in support of E-DCH operation based on type 1 enhanced receiver (Rx-Diversity) |  | 198d? | 2006-03-15 A | 2006-12-15 A | 100% |  | 2006-03-15 | 2006-12-15 | 198d? |  | finish no earlier than 2006-12-15 | R4 | 1584h | 1584h |  | Rel-7 | RInImp-RxDiv-EDCH | Serge Willenegger | sergew@qualcomm.com |  | MCC_RAN |  |
| 24 | 6.10 | Improved support of gaming over HSDPA/EDCH |  | 262d? | 2005-12-15 A | 2006-12-15 A | 100% |  | 2005-12-15 | 2006-12-15 | 262d? |  | finish no earlier than 2006-12-15 | R2 | 2096h | 2096h |  | Rel-7 | RInImp-Gaming | Don Zelmer, Cingular | don.zelmer@cingular.com |  | MCC_RAN |  |
| 25 | 6.11 | Interface to control Tower Mounted Amplifiers (TMAs) |  | 196d? | 2006-06-15 A | 2007-03-15 A | 100% |  | 2006-06-15 | 2007-03-15 | 196d? |  | finish no earlier than 2007-03-15 | R3 | 1568h | 1568h |  | Rel-7 | RInImp-TMA | Alexej Kulakov, Vodafone |  |  | MCC_RAN |  |
| 26 | 6.12 | OAM aspects to Interface to control TMAs |  | 101d? | 2007-01-26 | 2007-06-15 |  |  | 2007-01-26 | 2007-06-15 | 101d? | 175d | finish no earlier than 2007-06-15 | S5 | 808h |  |  | Rel-7 | RInImp-TMA-OAM | Adrian Neal, Vodafone |  |  | Adrian |  |
| 27 | 6.13 | Deleted (not approved at PCG) - UMTS 2.6 GHz FDD DL External | milestone | 0d? | 2005-09-15 A | 2005-09-15 A | 100% |  | 2005-09-15 | 2005-09-15 | 0d? |  | finish no earlier than 2005-09-15 | R4 |  |  |  | Rel-7 | RInImp-UMTS2600Ext | Han van Bussel | han.van.bussel@t-mobile.de | TSG | MCC_RAN | RP-31 |

Notes:
- 6: hchuang@Alcatel-Lucent.com / Text3: TR25.876,TR25.996
- 7: hchuang@Alcatel-Lucent.com / Text3: 25.211, 25.212, 25.213, 25.214, 25.215, 25.221, 25
- 8: hchuang@Alcatel-Lucent.com / Text3: TR 25.876
- 9: hchuang@Alcatel-Lucent.com
- 10: ngm@Alcatel-Lucent.com
- 12: Approved at RP#34 as RP-060681 / Text3: 25.806, 25.101, 25.104, 25.133, 24.141, 25.331, 25.306, 25.307, 25.423, 25.461, 25.463, 34.121
- 13: Approved at RP#33 as RP-060451 / Text3: 25.102, 25.105, 25.123, 25.113, 25.142, 34.124
- 14: Approved at RP#25 as RP-040377 / Text3: TS25.101, TS25.104, TS25.133, TS25.141, TS25.331, TS25.942, TS25.306, TS25.307, TS34.121
- 15: Text3: 25.102, 25.105, 25.113, 25.123, 25.142, 25.331, 25.942, 25.306, 25.307, 34.122, 34.124
- 16: Text3: 25.101, 25.104, 25.113, 25.133, 25.141, 25.331, 25.942, 25.306, 25.307, 34.121
- 17: Text3: 25.101, 25.104, 25.113, 25.133, 25.141, 25.306, 25.307, 25.331, 34.121
- 18: Text3: TS25.101, TS 25.963
- 19: Text3: 25.101
- 21: Text3: 25.101
- 22: Approved at RP#34 as RP-060678 / Text3: 25.101
- 23: Approved at RP#34 as RP-060679 / Text3: 25.101
- 24: Closed at RP#34 as RP-060680
- 26: AZ record created
- 27: This item was conditionnaly approved pending decision of PCG 16 who decided not to approve it / Text3: 25.101, 25.104, 25.133, 25.141, 25.331, 25.942, 25.306, 25.307, 34.121

| ID | WBS | Task | Duration | Start | Finish | Complete | Remaining | Baseline start | Baseline finish | Baseline duration | Total slack | Constraint | Resources | Work | Actual work | Text1 | Text4 | Text5 | Text6 | Text7 | Text8 |
| --- | --- | --- | --- | --- | --- | --- | --- | --- | --- | --- | --- | --- | --- | --- | --- | --- | --- | --- | --- | --- | --- |
| 28 | 7 | **7.68Mcps TDD option** | 457d? | 2004-09-15 A | 2006-06-15 A | 100% |  | 2004-09-15 | 2006-06-15 | 457d? |  |  | RP | 19824h | 19824h | VHCRTDD | Martin Beale, IPWireless | mbeale@ipwireless.com | Rel-7 | TSG | Claude |
| 29 | 7.1 | VHCRTDD: Stage 2 | 391d? | 2004-09-15 A | 2006-03-15 A | 100% |  | 2004-09-15 | 2006-03-15 | 391d? |  | finish no earlier than 2006-03-15 | R1 | 3128h | 3128h | VHCRTDD-Stage2 | Martin Beale, IPWireless | mbeale@ipwireless.com | Rel-7 | TSG | MCC_RAN |
| 30 | 7.2 | VHCRTDD: Physical Layer | 391d? | 2004-09-15 A | 2006-03-15 A | 100% |  | 2004-09-15 | 2006-03-15 | 391d? |  | finish no earlier than 2006-03-15 | R1 | 3128h | 3128h | VHCRTDD-Phys | Martin Beale, IPWireless | mbeale@ipwireless.com | Rel-7 | TSG | MCC_RAN |
| 31 | 7.3 | VHCRTDD: Layer 2 and layer 3 protocol aspects | 391d? | 2004-09-15 A | 2006-03-15 A | 100% |  | 2004-09-15 | 2006-03-15 | 391d? |  | finish no earlier than 2006-03-15 | R2 | 3128h | 3128h | VHCRTDD-L23 | Derek Richards, IPWireless | drichards@ipwireless.com | Rel-7 | TSG | MCC_RAN |
| 32 | 7.4 | VHCRTDD: UTRAN Iub/Iur Protocol Aspects | 391d? | 2004-09-15 A | 2006-03-15 A | 100% |  | 2004-09-15 | 2006-03-15 | 391d? |  | finish no earlier than 2006-03-15 | R3 | 3128h | 3128h | VHCRTDD-IurIub | Peter Legg, IPWireless | plegg@ipwireless.com | Rel-7 | TSG | MCC_RAN |
| 33 | 7.5 | VHCRTDD: RF Radio Transmission/ Reception, System Performance Requirements and Conformance Testing | 457d? | 2004-09-15 A | 2006-06-15 A | 100% |  | 2004-09-15 | 2006-06-15 | 457d? |  | finish no earlier than 2006-06-15 | R4 | 3656h | 3656h | VHCRTDD-RF | Shin Horng Wong | shwong@ipwireless.com | Rel-7 | TSG | MCC_RAN |
| 34 | 8 | **Rel-7 RAN improvements** | 644d? | 2004-12-15 A | 2007-06-04 | 93% | 44.08d? | 2004-12-15 | 2007-06-04 | 644d? | 184d |  | RP | 26656h | 20724.5h | RANimp |  |  | Rel-7 | TSG | MCC_RAN |
| 35 | 8.1 | Optimisation of channelisation code utilisation for 1.28 Mcps TDD | 523d? | 2004-12-15 A | 2006-12-15 A | 100% |  | 2004-12-15 | 2006-12-15 | 523d? |  | finish no earlier than 2006-12-15 | R1 | 4184h | 4184h | RANimp-RABSE-CodOptLCRTDD | Ka Leong Lo | kaleong.lo@utstar.com | Rel-7 | TSG | MCC_RAN |
| 36 | 8.2 | Delay optimisation for procedures applicable to CS and PS Connections | 394d? | 2005-03-15 A | 2006-09-15 A | 100% |  | 2005-03-15 | 2006-09-15 | 394d? |  | finish no earlier than 2006-09-15 | R2 | 3152h | 3152h | RANimp-DelayOpt | Juho Pirskanen | juho.pirskanen@nokia.com | Rel-7 | TSG | MCC_RAN |
| 37 | 8.3 | UE Performance Requirements for MBMS (TDD) | 328d? | 2005-03-15 A | 2006-06-15 A | 100% |  | 2005-03-15 | 2006-06-15 | 328d? |  | finish no earlier than 2006-06-15 | R4 | 2624h | 2624h | MBMS-RAN-RF-TDD | Shin Horng Wong | shwong@ipwireless.com | Rel-7 | TSG | MCC_RAN |
| 38 | 8.4 | Continuous connectivity for packet data users | 524d? | 2005-03-14 A | 2007-03-15 A | 100% |  | 2005-03-14 | 2007-03-15 | 524d? |  | finish no earlier than 2007-03-15 | R1 | 4192h | 4192h | RANimp-CPC | Joern Krause | Joern.Krause@siemens.com | Rel-7 | TSG | MCC_RAN |
| 39 | 8.5 | Extended WCDMA Cell Range | 198d? | 2006-03-15 A | 2006-12-15 A | 100% |  | 2006-03-15 | 2006-12-15 | 198d? |  | finish no earlier than 2006-12-15 | R3 | 1584h | 1584h | RANimp-ExtCell | Ericsson |  | Rel-7 |  | MCC_RAN |
| 40 | 8.6 | 7.68 Mcps TDD Enhanced Uplink | 198d? | 2006-03-15 A | 2006-12-15 A | 100% |  | 2006-03-15 | 2006-12-15 | 198d? |  | finish no earlier than 2006-12-15 | R1 | 1584h | 1584h | RANimp-VHCRTDD-EDCH | Nicholas Anderson | nanderson@ipwireless.com | Rel-7 |  | MCC_RAN |
| 41 | 8.7 | Enhanced CELL_FACH State in FDD | 181d? | 2006-09-25 A | 2007-06-04 | 75% | 46d? | 2006-09-25 | 2007-06-04 | 181d? | 184d | finish no earlier than 2007-06-04 | R2 | 1448h | 1080h | RANimp-EnhState | Juho Pirskanen, Nokia | juho.pirskanen@nokia.com | Rel-7 |  | MCC_RAN |
| 42 | 8.8 | 64QAM for HSDPA (FDD) | 110d? | 2006-12-15 A | 2007-06-04 | 58% | 46d? | 2006-12-15 | 2007-06-04 | 110d? | 184d | finish no earlier than 2007-06-04 | R1 | 880h | 512h | RANimp-64QamDownlink | Johan Bergman | Johan.Bergman@ericsson.com | Rel-7 |  | MCC_RAN |
| 43 | 8.9 | Improved L2 support for high data rates | 122d? | 2006-12-15 A | 2007-06-04 | 62% | 46d? | 2006-12-15 | 2007-06-04 | 122d? | 184d | finish no earlier than 2007-06-04 | R2 | 976h | 608h | RANimp-L2DataRates | Janne Peisa | Janne.Peisa@ericsson.com | Rel-7 |  | MCC_RAN |
| 44 | 8.10 | Introduction of 16QAM in HSUPA (FDD) | 110d? | 2006-12-15 A | 2007-06-04 | 58% | 46d? | 2006-12-15 | 2007-06-04 | 110d? | 184d | finish no earlier than 2007-06-04 | R1 | 880h | 512h | RANimp-16QamUplink | Karri Ranta-aho | karri.ranta-aho@nokia.com | Rel-7 |  | MCC_RAN |
| 45 | 9 | **3.84 Mcps TDD Enhanced Uplink** | 394d? | 2005-03-15 A | 2006-09-15 A | 100% |  | 2005-03-15 | 2006-09-15 | 394d? |  |  | RP | 18384h | 18384h | EDCHTDD | Nicholas Anderson | nanderson@ipwireless.com | Rel-7 | TSG | MCC_RAN |
| 46 | 9.1 | EDCHTDD: Stage 2 | 328d? | 2005-03-15 A | 2006-06-15 A | 100% |  | 2005-03-15 | 2006-06-15 | 328d? |  | finish no earlier than 2006-06-15 | R2 | 2624h | 2624h | EDCHTDD-Stage2 | Nicholas Anderson | nanderson@ipwireless.com | Rel-7 | TSG | MCC_RAN |
| 47 | 9.2 | EDCHTDD: Physical Layer | 394d? | 2005-03-15 A | 2006-09-15 A | 100% |  | 2005-03-15 | 2006-09-15 | 394d? |  | finish no earlier than 2006-09-15 | R1 | 3152h | 3152h | EDCHTDD-Phys | Nicholas Anderson | nanderson@ipwireless.com | Rel-7 | TSG | MCC_RAN |
| 48 | 9.3 | EDCHTDD: Layer 2 and 3 Protocol Aspects | 394d? | 2005-03-15 A | 2006-09-15 A | 100% |  | 2005-03-15 | 2006-09-15 | 394d? |  | finish no earlier than 2006-09-15 | R2 | 3152h | 3152h | EDCHTDD-L23 | Derek Richards | drichards@ipwireless.com | Rel-7 | TSG | MCC_RAN |
| 49 | 9.4 | EDCHTDD: UTRAN Iub/Iur Protocol Aspects | 394d? | 2005-03-15 A | 2006-09-15 A | 100% |  | 2005-03-15 | 2006-09-15 | 394d? |  | finish no earlier than 2006-09-15 | R3 | 3152h | 3152h | EDCHTDD-IurIub | Jim Miller | jim.miller@interdigital.com | Rel-7 | TSG | MCC_RAN |
| 50 | 9.5 | EDCHTDD: RF Radio Transmission/ Reception, System Performance Requirements and Conformance Testing | 394d? | 2005-03-15 A | 2006-09-15 A | 100% |  | 2005-03-15 | 2006-09-15 | 394d? |  | finish no earlier than 2006-09-15 | R4 | 3152h | 3152h | EDCHTDD-RF | Shin Horng Wong | shwong@ipwireless.com | Rel-7 | TSG | MCC_RAN |
| 51 | 10 | **1.28 Mcps TDD Enhanced Uplink** | 328d? | 2006-03-15 A | 2007-06-15 | 89% | 35.04d? | 2006-03-15 | 2007-06-15 | 328d? | 175d |  | RP | 11536h | 8590.27h | LCRTDD-EDCH | Haijing Hu (CATT) |  | Rel-7 |  | MCC_RAN |
| 52 | 10.1 | 1.28 Mcps TDD Enhanced Uplink: Physical Layer | 262d? | 2006-03-15 A | 2007-03-15 A | 100% |  | 2006-03-15 | 2007-03-15 | 262d? |  | finish no earlier than 2007-03-15 | R1 | 2096h | 2096h | LCRTDD-EDCH-Phys | Ke Wang (CATT) |  | Rel-7 |  | MCC_RAN |
| 53 | 10.2 | 1.28 Mcps TDD Enhanced Uplink: Layer 2 and 3 Protocol Aspects | 262d? | 2006-03-15 A | 2007-03-15 A | 100% |  | 2006-03-15 | 2007-03-15 | 262d? |  | finish no earlier than 2007-03-15 | R2 | 2096h | 2096h | LCRTDD-EDCH-L23 | Haiyang Quan (CATT) |  | Rel-7 |  | MCC_RAN |
| 54 | 10.3 | 1.28 Mcps TDD Enhanced Uplink: UTRAN Iub/Iur Protocol Aspects | 262d? | 2006-03-15 A | 2007-03-15 A | 100% |  | 2006-03-15 | 2007-03-15 | 262d? |  | finish no earlier than 2007-03-15 | R3 | 2096h | 2096h | LCRTDD-EDCH-IubIur | Yincheng Zhang (CATT) |  | Rel-7 |  | MCC_RAN |
| 55 | 10.4 | 1.28 Mcps TDD Enhanced Uplink: RF Radio Transmission/ Reception, System Performance Requirements and Conformance Testing | 328d? | 2006-03-15 A | 2007-06-15 | 64% | 119d? | 2006-03-15 | 2007-06-15 | 328d? | 175d | finish no earlier than 2007-06-15 | R4 | 2624h | 1672h | LCRTDD-EDCH-RF | Yuexia Song (CATT) |  | Rel-7 |  | MCC_RAN |

Notes:
- 28: Approved at RP#25 as RP-040365
- 29: Feature completed and closed at RP#33 with the presentation of the test WI / Text3: TS25.202
- 30: Feature completed and closed at RP#33 with the presentation of the test WI / Text3: TS25.221, TS25.222, TS25.223, TS25.224,TS25.225
- 31: Feature completed and closed at RP#33 with the presentation of the test WI / Text3: TS25.301, TS25.302, TS25.305, TS25.306, TS25.321, TS25.331
- 32: Feature completed and closed at RP#33 with the presentation of the test WI / Text3: TS25.401, TS25.420, TS25.423, TS25.425, TS25.427, TS25.430, TS25.433, TS25.435
- 33: Feature completed and closed at RP#33 with the presentation of the test WI / Text3: TS25.102, TS25.105, TS25.123, TS25.133, TS25.142
- 34: Generic feature
- 35: Approved at RP#34 as RP-060682
- 36: Approved at RP#33 as RP-060453 / Text3: TS25.321, TS25.322, TS25.331
- 37: WI completed and closed with the presentation of the test WI / Text3: TS25.102, TS25.123
- 39: Approved at RP#34 as RP-060685 / Text3: 25.133, 25.423, 25.425, 25.433, 25.435, 25.453, 25.331
- 40: Approved at RP#34 as RP-060684 / Text3: 25.201, 25.202, 25.221, 25.222, 25.223, 25.224, 25.225, 25.331, 23.321, 25.306, 25.302, 25.401, 25.420, 25.423, 25.427, 25.433, 25.102, 25.105, 25.142
- 41: WI Acronym corrected / Text3: 25.308, 25.304, 25.306, 25.321, 25.331, 25.433, 25.435, 25.423, 25.425,
- 42: Text3: 25.308, 25.211, 25.212, 25.213, 25.306, 25.331, 25.433, 25.435, 25.423, 25.425, 25.101, 25.104, 25.141
- 43: Text3: 25.301, 25.306, 25.321, 25.322, 25.331, 25.433, 25.435, 25.423, 25.425
- 44: Text3: 25.319, 25.101, 25.104, 25.133, 25.141, 25.211, 25.212, 25.213, 25.214, 25.306, 25.321, 25.331, 25.423, 25.433
- 45: Approved at RP#33 as RP-060462
- 47: Text3: TS25.201, TS25.221,TS25.222, TS25.223, TS25.224, TS25.225
- 48: Text3: TS25.301, TS25.302, TS25.306, TS25.321, TS25.331
- 49: Text3: TS25.401, TS25.420, TS25.423, TS25.427, TS25.430, TS25.433, TS25.435
- 50: Text3: TS25.102, TS25.105, TS25.123, TS25.142
- 52: Text3: 25.201, 25.221, 25.222, 25.223, 25.224, 25.225
- 53: Text3: 25.301, 25.302, 25.306, 25.321, 25.331
- 54: Text3: 25.401, 25.420, 25.423, 25.425, 25.427, 25.430, 25.433, 25.435
- 55: Text3: 25.102, 25.105, 25.123, 25.142

| ID | WBS | Task | Type | Duration | Start | Finish | Complete | Remaining | Baseline start | Baseline finish | Baseline duration | Total slack | Constraint | Resources | Work | Actual work | Text1 | Text4 | Text6 | Text7 | Text8 | Text2 | Text3 | Text9 | Text5 | Text12 |
| --- | --- | --- | --- | --- | --- | --- | --- | --- | --- | --- | --- | --- | --- | --- | --- | --- | --- | --- | --- | --- | --- | --- | --- | --- | --- | --- |
| 56 | 11 | **PS domain and IMS impacts for supporting IMS Emergency calls** |  | 1770d? | 2000-09-18 A | 2007-06-29 | 79% | 366.54d? | 2000-09-18 | 2007-06-29 | 1770d? | 165d |  | S2 | 48037h | 37543.1h | EMC1 | Rainer Liebhart | Rel-7 | TSG | Maurice |  |  |  |  |  |
| 57 | 10.1.1 | Service Requirements for IP-based emergency calls |  | 985d | 2000-09-18 A | 2004-06-25 A | 100% |  | 2000-09-18 | 2004-06-25 | 985d |  | finish no earlier than 2004-06-25 | S1 | 7880h | 7880h | EMC1 |  | Rel-7 |  |  | CCaR | 22.976 | 1314 |  |  |
| 58 | 11.2 | Study on Stage 2 for IMS-level solution |  | 668d? | 2003-02-26 A | 2005-09-16 A | 100% |  | 2003-02-26 | 2005-09-16 | 668d? |  | finish no earlier than 2005-09-16 | S2 | 5344h | 5344h | EMC1 | Rainer Liebhart, Siemenws | Rel-7 | TSG |  |  | 23.228, 23.060, 23.002 |  |  |  |
| 59 | 11.3 | Study on Stage 2 for GPRS-level solution |  | 301d? | 2004-10-14 A | 2005-12-08 A | 100% |  | 2004-10-14 | 2005-12-08 | 301d? |  | finish no earlier than 2005-12-08 | S2 | 2408h | 2408h | EMC1 |  | Rel-7 |  |  |  |  |  |  |  |
| 60 | 11.4 | Stage 2 Specification Phase - IMS-level |  | 200d? | 2005-09-05 A | 2006-06-09 A | 100% |  | 2005-09-05 | 2006-06-09 | 200d? |  | finish no earlier than 2006-06-09 | S2 | 1600h | 1600h | EMC1 |  | Rel-7 |  |  |  |  |  |  |  |
| 61 | 11.5 | Stage 2 Specification Phase - GPRS-level |  | 475d? | 2005-09-05 A | 2007-06-29 | 37% | 299.5d? | 2005-09-05 | 2007-06-29 | 475d? | 165d | finish no earlier than 2007-03-02 | S2 | 3800h | 1404h | EMC1 |  | Rel-7 |  |  |  |  |  |  |  |
| 62 | 10.1 | **Emergency Call Enhancements for IP& PS Based Calls – stage 3** |  | 375d | 2006-01-09 A | 2007-06-15 | 60% | 150.8d | 2006-01-09 | 2007-06-15 | 375d | 175d |  | C1 | 12845h | 7679.48h | EMC1 | Alf Heidermark (Ericsson) | Rel-7 |  |  | CCaR |  | 1653 | alf.heidermark@ericsson.com |  |
| 63 | 10.1.2 | CT1 IMS aspects to support IMS Emergency sessions |  | 350.82d | 2006-01-09 A | 2007-06-15 | 95% | 17.54d | 2006-01-09 | 2007-06-15 | 350.82d | 175d | finish no earlier than 2007-06-15 | C1 | 2806.56h | 2666.23h | EMC1 | Alf Heidermark (Ericsson) | Rel-7 |  |  | CCaR | 24.229 | 1315 | alf.heidermark@ericsson.com |  |
| 64 | 10.1.2 | CT3 IMS aspects to support IMS Emergency sessions |  | 95d | 2006-05-08 A | 2006-09-15 | 40% | 57d | 2006-05-08 | 2006-09-15 | 95d | 370d | finish no earlier than 2006-09-15 | C3 | 760h | 304h | EMC1 | Alf Heidermark (Ericsson) | Rel-7 |  |  | CCaR | 29.163 | 1315 | alf.heidermark@ericsson.com |  |
| 65 | 10.1.5 | CT3 PS domain aspects to support IMS Emergency sessions |  | 95d | 2006-05-08 A | 2006-09-15 | 40% | 57d | 2006-05-08 | 2006-09-15 | 95d | 370d | start no earlier than 2006-05-08 | C3 | 760h | 304h | EMC1 | Alf Heidermark (Ericsson) | Rel-7 |  |  | CCaR | 29.061 | 1646 | alf.heidermark@ericsson.com |  |
| 66 | 10.1.5 | CT1 PS domain aspects to support IMS Emergency sessions |  | 349.9d | 2006-01-09 A | 2007-06-15 | 35% | 227.44d | 2006-01-09 | 2007-06-15 | 349.9d | 175d | finish no earlier than 2007-06-15 | C1 | 2799.2h | 979.72h | EMC1 | Alf Heidermark (Ericsson) | Rel-7 |  |  | CCaR | 24.008, 24.234 | 1646 | alf.heidermark@ericsson.com |  |
| 67 | 10.1.5 | CT4 PS domain aspects to support IMS Emergency sessions |  | 365d | 2006-01-09 A | 2007-06-01 | 60% | 146d | 2006-01-09 | 2007-06-01 | 365d | 185d | finish no earlier than 2007-06-01 | C4 | 2920h | 1752h | EMC1-GPRSc4 | Alf Heidermark (Ericsson) | Rel-7 |  |  | CCaR | 29.060 | 1646 | alf.heidermark@ericsson.com |  |
| 68 | 12 | **Access Class Barring and Overload Protection** |  | 650d? | 2004-03-15 A | 2006-09-08 A | 100% |  | 2004-03-15 | 2006-09-08 | 650d? |  |  | S2 | 8768h | 8768h | ACBOP | Chris Pudney, Vodafone | Rel-7 | TSG | Maurice |  | 23.898 |  |  |  |
| 69 | 12.1 | TR on Stage 2 |  | 274d? | 2004-03-15 A | 2005-03-31 A | 100% |  | 2004-03-15 | 2005-03-31 | 274d? |  | finish no earlier than 2005-03-31 | S2 | 2192h | 2192h | ACBOP |  | Rel-7 | TSG |  |  |  |  |  |  |
| 70 | 12.2 | Stage 3 CN aspects of ACBOP |  | 172d? | 2005-06-06 A | 2006-01-31 A | 100% |  | 2005-06-06 | 2006-01-31 | 172d? |  | start no earlier than 2005-06-06 | C1 | 1376h | 1376h | ACBOP |  | Rel-7 |  |  |  | 24.008 |  |  |  |
| 71 | 12.3 | Deleted - Potential impact on Iu interface Overload functionality | milestone | 0d? | 2004-03-15 A | 2004-03-15 A | 100% |  | 2004-03-15 | 2004-03-15 | 0d? |  | finish no earlier than 2004-03-15 | RP |  |  | ACBOP |  | Rel-7 |  |  |  | 25.413 |  |  | RP-25 |
| 72 | 12.4 | Deleted - Extra ACBOP information in RAN | milestone | 0d? | 2004-03-15 A | 2004-03-15 A | 100% |  | 2004-03-15 | 2004-03-15 | 0d? |  | finish no earlier than 2004-03-15 | RP |  |  | ACBOP |  | Rel-7 |  |  |  | 25.331 |  |  | RP-25 |
| 73 | 12.5 | Deleted - Extra ACBOP information in GERAN | milestone | 0d? | 2006-09-08 A | 2006-09-08 A | 100% |  | 2006-09-08 | 2006-09-08 | 0d? |  | start no earlier than 2006-09-08 | GP |  |  | ACBOP |  | Rel-7 | TSG | Gert |  | 44.018 |  |  | RP-33 |
| 74 | 13 | **USSD message delivery and transfer to USIM** |  | 376d? | 2004-03-05 A | 2005-08-12 A | 100% |  | 2004-03-05 | 2005-08-12 | 376d? |  |  | S1 | 5698.4h | 5698.4h | USSD-USIM |  | Rel-7 | TSG | Michael |  | 22.090 |  |  |  |
| 75 | 13.1 | Stage 1 |  | 152d? | 2004-03-18 A | 2004-10-15 A | 100% |  | 2004-03-18 | 2004-10-15 | 152d? |  | start no earlier than 2004-03-18 | S1 | 1216h | 1216h | USSD-USIM |  | Rel-7 | TSG | Michael |  | 22.090 |  |  |  |
| 76 | 13.2 | Alignment with requirements regarding USSD usage |  | 193.3d? | 2004-03-05 A | 2005-08-12 A | 100% |  | 2004-03-05 | 2005-08-12 | 193.3d? |  | finish no earlier than 2005-08-12 | C6 | 1546.4h | 1546.4h | USSD-USIM | Christophe Dubois (Axalto) | Rel-7 | TSG |  |  |  |  | cdubois@axalto.com |  |
| 77 | 14 | **Location Services enhancements Rel-7** |  | 766d? | 2004-06-28 A | 2007-06-04 | 84% | 122.45d? | 2004-06-28 | 2007-06-04 | 766d? | 184d |  | S2 | 42973.6h | 29443.3h | LCS3 |  | Rel-7 |  | Maurice |  | 23.271 |  |  |  |
| 78 | 14.1 | Global Stage 2 for LCS3 (including IMS emergency location aspects) |  | 446d? | 2004-12-31 A | 2006-09-15 A | 100% |  | 2004-12-31 | 2006-09-15 | 446d? |  | finish no earlier than 2006-09-15 | S2 | 3568h | 3568h | LCS3 | Ben Rodilitz, SiRF | Rel-7 | TSG | Maurice |  | 23.271 |  | brodilitz@sirf.com |  |
| 79 | 14.2 | CT4 aspects for LCS |  | 240d? | 2006-01-02 A | 2006-12-01 A | 100% |  | 2006-01-02 | 2006-12-01 | 240d? |  | finish no earlier than 2006-12-01 | C4 | 1920h | 1920h | LCS3-UEPos-LBS |  | Rel-7 | TSG |  |  |  |  |  |  |

Notes:
- 66: end date updated by CT1-chairman after CT#33
- 67: CRs Approved in WLAN 40 % done after CT4#33
- 70: NEW - inserted on 2/9/2004
- 78: Approved SA#27. Appropriate place forEmergency work to be found
- 79: CRs approved in CT4#30...

| ID | WBS | Task | Type | Duration | Start | Finish | Complete | Remaining | Baseline start | Baseline finish | Baseline duration | Total slack | Constraint | Resources | Work | Actual work | Text1 | Text6 | Text7 | Text8 | Text5 | Text12 |
| --- | --- | --- | --- | --- | --- | --- | --- | --- | --- | --- | --- | --- | --- | --- | --- | --- | --- | --- | --- | --- | --- | --- |
| 80 | 14.3 | **LCS for 3GPP Interworking WLAN** |  | 700d? | 2004-06-28 A | 2007-03-02 | 99% | 0d? | 2004-06-28 | 2007-03-02 | 700d? | 0d |  | S1 | 11901.6h | 6400h | LCS3-IWLAN | Rel-7 | TSG | Michael |  |  |
| 81 | 14.3.1 | FS on 3GPP system to WLAN Interworking with LCS |  | 512.7d? | 2004-06-28 A | 2006-06-30 A | 100% |  | 2004-06-28 | 2006-06-30 | 512.7d? |  | finish no earlier than 2005-09-29 | S1 | 4101.6h | 4101.6h | LCS3-IWLAN | Rel-7 |  |  |  |  |
| 82 | 14.3.2 | Study of work on an LCS architecture for I-WLAN. |  | 180d? | 2006-06-26 A | 2007-03-02 A | 100% |  | 2006-06-26 | 2007-03-02 | 180d? |  | finish no earlier than 2007-03-02 | S2 | 1440h | 1440h | LCS3-IWLAN | Rel-7 |  | Maurice | dhshim@lge.com ; phede@lge.com |  |
| 83 | 14.3.3 | Stage 2 CRs for LCS architecture for I-WLAN. |  | 95d? | 2006-10-23 A | 2007-03-02 A | 100% |  | 2006-10-23 | 2007-03-02 | 95d? |  | finish no earlier than 2007-03-02 | S2 | 760h | 760h | LCS3-IWLAN | Rel-7 |  | Maurice |  |  |
| 84 | 14.4 | **UE positioning Rel-7** |  | 709d? | 2004-09-15 A | 2007-06-04 | 94% | 46d? | 2004-09-15 | 2007-06-04 | 709d? | 184d |  | RP | 11344h | 8014.84h | LCS3-UEpos | Rel-7 | TSG | Claude |  |  |
| 85 | 14.4.1 | Inclusion of Uplink TDOA UE positioning method in the UTRAN specifications |  | 709d? | 2004-09-15 A | 2007-06-04 | 94% | 46d? | 2004-09-15 | 2007-06-04 | 709d? | 184d | finish no earlier than 2007-06-04 | R2 | 5672h | 5304h | LCS3-UEPos-UTDOA | Rel-7 | TSG | MCC_RAN | rlgross@trueposition.com |  |
| 86 | 14.5 | UE positioning - Velocity |  | 394d? | 2005-03-15 A | 2006-09-15 A | 100% |  | 2005-03-15 | 2006-09-15 | 394d? |  | finish no earlier than 2006-09-15 | R2 | 3152h | 3152h | LCS3-UEPos-Velocity | Rel-7 | TSG | MCC_RAN | BRodilitz@SiRF.com |  |
| 87 | 14.6 | LCS Enhancements Related to Location-Based Services |  | 620d? | 2005-01-03 A | 2007-05-18 | 25% | 465d? | 2005-01-03 | 2007-05-18 | 620d? | 195d | finish no earlier than 2007-02-16 | GP | 4960h | 1240h | LCS3-LBS | Rel-7 | TSG | Paolo | kjudge@sirf.com |  |
| 88 | 14.7 | Deleted - RAN2 aspects for LBS | milestone | 0d? | 2005-06-15 A | 2005-06-15 A | 100% |  | 2005-06-15 | 2005-06-15 | 0d? |  | start no earlier than 2005-06-15 | R2 |  |  | LCS3-UEPos-LBS | Rel-7 | TSG | MCC_RAN | BRodilitz@SiRF.com | RP-31 |
| 89 | 15 | A-GPS Minimum Performance |  | 276d? | 2006-04-28 A | 2007-05-18 | 80% | 55.2d? | 2006-04-28 | 2007-05-18 | 276d? | 195d | finish no earlier than 2007-05-18 | G1; G3 | 2208h | 1766.4h | GAGR | Rel-7 |  | Paolo | richard.catmur@spirentcom.com |  |
| 90 | 16 | **Advanced Global Navigation Satellite System (A-GNSS) concept** |  | 766d? | 2004-06-28 A | 2007-06-04 | 73% | 205.49d? | 2004-06-28 | 2007-06-04 | 766d? | 184d |  | S1 | 15081.6h | 6702.08h | LCS3-AGNSS | Rel-7 | TSG | Michael | Michel.monnerat@space.alcatel.fr |  |
| 91 | 16.1 | Deleted - Towards A-GNSS Concept | milestone | 0d? | 2007-02-16 A | 2007-02-16 A | 100% |  | 2007-02-16 | 2007-02-16 | 0d? |  | start no earlier than 2007-02-16 | S1 |  |  | GNSS | Rel-7 | TSG | Paolo | richard.couty@space.alcatel.fr | SP-34 |
| 92 | 16.2 | Towards A-GNSS Concept |  | 736.2d? | 2004-06-28 A | 2007-05-18 | 80% | 147.24d? | 2004-06-28 | 2007-05-18 | 736.2d? | 195d | finish no earlier than 2007-05-18 | GP | 5889.6h | 4711.68h | AGNSS-GP | Rel-7 | TSG | Paolo | richard.couty@space.alcatel.fr |  |
| 93 | 16.3 | Global Navigation Satellite System (GNSS) in UTRAN |  | 383d? | 2005-12-15 A | 2007-06-04 | 60% | 153d? | 2005-12-15 | 2007-06-04 | 383d? | 184d | finish no earlier than 2007-06-04 | R2 | 3064h | 1840h | LCS3-GNSS-UTRAN | Rel-7 |  | MCC_RAN | alain.abinakhoul@francetelecom.com |  |
| 94 | 17 | **Combinational Services** |  | 296d? | 2005-01-17 A | 2006-03-06 A | 100% |  | 2005-01-17 | 2006-03-06 | 296d? |  |  | S1 | 7544h | 7544h | CSICS | Rel-7 | TSG | Michael | Robert.Frank@teliasonera.com |  |
| 95 | 17.1 | Stage 1 for CSICS |  | 104d? | 2005-01-17 A | 2005-06-09 A | 100% |  | 2005-01-17 | 2005-06-09 | 104d? |  | start no earlier than 2005-01-17 | S1 | 832h | 832h | CSICS | Rel-7 | TSG |  |  |  |
| 96 | 17.2 | Stage 2 for CSICS |  | 130d? | 2005-01-17 A | 2005-07-15 A | 100% |  | 2005-01-17 | 2005-07-15 | 130d? |  | start no earlier than 2005-01-17 | S2 | 1040h | 1040h | CSICS | Rel-7 |  |  |  |  |
| 97 | 17.3 | Stage 3 for CSICS CN aspects |  | 221d? | 2005-05-02 A | 2006-03-06 A | 100% |  | 2005-05-02 | 2006-03-06 | 221d? |  | finish no earlier than 2006-03-06 | C1 | 1768h | 1768h | CSICS | Rel-7 | TSG | Andrijana |  |  |
| 98 | 17.4 | Stage 3 for codec aspects |  | 192d? | 2005-03-15 A | 2005-12-07 A | 100% |  | 2005-03-15 | 2005-12-07 | 192d? |  | finish no earlier than 2005-12-07 | S4 | 1536h | 1536h | CSICS-Codec | Rel-7 | TSG | Paolo | Per.Frojdh@ericsson.com |  |
| 99 | 18 | **System enhancements for fixed broadband access to IMS** |  | 876d? | 2003-11-05 A | 2007-03-15 | 98% | 20.02d? | 2003-11-05 | 2007-03-15 | 876d? | 242d |  | S2 | 42721.6h | 32888.3h | FBI | Rel-7 | TSG | Maurice |  |  |
| 100 | 18.1 | **TISPAN Rel 1 related aspects** |  | 873d? | 2003-11-05 A | 2007-03-09 | 97% | 25.26d? | 2003-11-05 | 2007-03-09 | 873d? | 245d |  | S2 | 31568h | 23984h | FBI | Rel-7 |  |  |  |  |
| 101 | 18.1.1 | Stage 2 of FBI for TISPAN R1 |  | 365d? | 2004-10-14 A | 2006-03-08 A | 100% |  | 2004-10-14 | 2006-03-08 | 365d? |  | start no earlier than 2004-10-14 | S2 | 2920h | 2920h | FBI | Rel-7 |  | Maurice |  |  |
| 102 | 18.1.2 | **Protocol impact of FBI for TISPAN R1** |  | 873d? | 2003-11-05 A | 2007-03-09 | 99% | 7.38d? | 2003-11-05 | 2007-03-09 | 873d? | 245d |  | C1 | 20720h | 20544.8h | FBI | Rel-7 | TSG | Andrijana |  |  |
| 103 | 18.1.2.1 | CT1 aspects of FBI for TISPAN R1 |  | 802d? | 2003-11-05 A | 2006-11-30 A | 100% |  | 2003-11-05 | 2006-11-30 | 802d? |  | finish no earlier than 2006-11-30 | C1 | 6416h | 6416h | FBI | Rel-7 | TSG | Andrijana |  |  |
| 104 | 18.1.2.2 | CT3 aspects of FBI for TISPAN R1 |  | 808d? | 2003-11-05 A | 2006-12-08 | 98% | 16.16d? | 2003-11-05 | 2006-12-08 | 808d? | 310d | finish no earlier than 2006-12-08 | C3 | 6464h | 6334.72h | FBI | Rel-7 | TSG | Andrijana |  |  |
| 105 | 18.1.2.3 | CT4 aspects of FBI for TISPAN R1 |  | 301d? | 2006-01-13 A | 2007-03-09 A | 100% |  | 2006-01-13 | 2007-03-09 | 301d? |  | finish no earlier than 2007-03-09 | C4 | 2408h | 2408h | FBI-TIS1-st3-c4 | Rel-7 | TSG | Andrijana |  |  |
| 106 | 18.1.3 | Security Enhancements for FBI |  | 118d? | 2005-06-28 A | 2005-12-08 | 55% | 53.1d? | 2005-06-28 | 2005-12-08 | 118d? | 571d | start no earlier than 2005-06-28 | S3 | 944h | 519.2h | FBI-ISE | Rel-7 |  | Mike | Bengt.Sahlin@ericsson.com |  |

Notes:
- 80: Text3: 22.935 / Text4: Mike Loushine, (Telcordia)
- 81: DAB - Should be SA1 / Text3: 22.935
- 82: Updated WID at SA#32 to change "stage 2" to "study" , duplicated UID 320017 deleted. Exception Granted for Rel-7 until 03/07 / Text3: 23.837 / Text4: Donghee Shim (LG Electronics Inc.); Patrice HÉDÉ (LG Electronics Mobilecomm France)
- 83: WID at SA#55
- 85: Text3: TS25.305, TS25.453 / Text4: Robert Gross, TruePosition
- 86: Approved at RP#33 as RP-060459 / Text3: 25.305, 25.331, 25.410, 25.413, 25.453 / Text4: Ben Rodilitz
- 87: Linked to SP-040682 / Text3: 43.059, 44.031, 48.008, 49.031 / Text4: Kevin Judge, SiRF Technologies
- 88: Text3: 25.305, 25.331, 25.410, 25.413, 25.453 / Text4: Ben Rodilitz
- 89: Text3: 45.005, 51.010 / Text4: Richard Catmur, Spirent Communications
- 90: Text4: Michel MONNERAT
- 91: Text4: Richard Couty, ALCATEL SA
- 92: Started / Text4: Richard Couty, ALCATEL SA
- 93: Text3: TS 25.305,TS 25.331,TS 25.306,TS 25.413,TS 25.423,TS 25.433,TS 25.453,TS 25.171,TS 34.171 / Text4: Alain Abinakhoul, France Telecom
- 94: Text4: Robert Frank, TeliaSonera
- 95: Text3: 22.279
- 96: Text3: 23.279
- 97: Text3: New TS 24.279, 24.229, 24.008 / Text4: Peter Dawes (Vodafone)
- 98: Started / Text3: TS 26.141, 26.235, 26.236 / Text4: Per Fröjdh, Ericsson
- 102: Text3: new TR 24.819, 24.229, 29.229, 29.163, 29.209 / Text4: Peter Leis (Siemens)
- 103: end date updated by CT1-chairman after CT#33 / Text3: new TR 24.819, 24.229, 29.229, 29.163, 29.209 / Text4: Siemens
- 104: Text3: new TR, 29.229, 29.163 / Text4: Siemens
- 105: CT4#32: a set of CRs on FBI for cable labs / Text3: 29.209 / Text4: Siemens
- 106: Duplicated entry ("ACCSEC2", "Access Security Enhancements", SP-040865) deleted by A.Sultan / Text3: 33.102, 43.020 / Text4: Bengt Sahlin, Ericsson

| ID | WBS | Task | Duration | Start | Finish | Complete | Remaining | Baseline start | Baseline finish | Baseline duration | Total slack | Constraint | Resources | Work | Actual work | Text1 | Text6 | Text3 | Text4 | Text5 | Text8 | Text7 | Text12 |
| --- | --- | --- | --- | --- | --- | --- | --- | --- | --- | --- | --- | --- | --- | --- | --- | --- | --- | --- | --- | --- | --- | --- | --- |
| 107 | 18.2 | **PacketCable Related aspects** | 291d? | 2006-02-01 A | 2007-03-15 | 99% | 0d? | 2006-02-01 | 2007-03-15 | 291d? | 0d |  | S2 | 7248h | 5088h | FBI-PCBL | Rel-7 |  |  |  |  |  |  |
| 108 | 18.2.1 | Stage 2 of FBI for PacketCable | 228d? | 2006-02-01 A | 2006-12-15 A | 100% |  | 2006-02-01 | 2006-12-15 | 228d? |  | finish no earlier than 2006-12-15 | S2 | 1824h | 1824h | FBI-PCBL | Rel-7 |  |  |  |  |  |  |
| 109 | 18.2.2 | Protocol impact of FBI for PacketCable | 228d? | 2006-05-01 A | 2007-03-15 A | 100% |  | 2006-05-01 | 2007-03-15 | 228d? |  | finish no earlier than 2007-03-15 | C1 | 1824h | 1824h | FBI-PCBL | Rel-7 |  |  |  |  |  |  |
| 110 | 18.2.3 | SA5 Charging aspects of FBI for PacketCable | 180d? | 2006-03-31 A | 2006-12-07 A | 100% |  | 2006-03-31 | 2006-12-07 | 180d? |  | finish no earlier than 2006-12-07 | S5 | 1440h | 1440h | FBI-PCBL-CH | Rel-7 | 32.240, 32.260, 32.298, 32.299 | CableLabs | Bernie McKibben | Adrian |  |  |
| 111 | 19 | Access Security Enhancements | 195d? | 2005-01-03 A | 2005-09-30 | 75% | 48.75d? | 2005-01-03 | 2005-09-30 | 195d? | 620d | finish no earlier than 2005-09-30 | S3 | 1560h | 1170h | ACCSEC2 | Rel-7 | 33.102, 43.020 | Bengt Sahlin, Ericsson | Bengt.Sahlin@ericsson.com | Michael | TSG |  |
| 112 | 20 | **Mp (MRFC - MRFP) interface** | 345d? | 2006-02-13 A | 2007-06-08 | 66% | 117.35d? | 2006-02-13 | 2007-06-08 | 345d? | 180d |  | C4 | 7144h | 4714h | Mp | Rel-7 |  | Phil Hodges, Ericsson | philip.hodges@ericsson.com | Kimmo |  |  |
| 113 | 20.1 | CT1 aspects of Mp | 1d | 2006-02-13 | 2006-02-13 |  |  | 2006-02-13 | 2006-02-13 | 1d | 524d | finish no earlier than 2006-02-13 | C1 | 8h |  | Mp | Rel-7 | 24.229 | Ericsson |  |  |  |  |
| 114 | 20.2 | Deleted - CT3 aspects of Mp | 1d | 2006-09-22 A | 2006-09-22 A | 100% |  | 2006-09-22 | 2006-09-22 | 1d |  | start no earlier than 2006-09-22 | C3 | 8h | 8h | Mp | Rel-7 | 29.162 | Ericsson |  |  |  | CP-33 |
| 115 | 20.3 | Procedures description | 201d? | 2006-06-02 A | 2007-03-09 | 85% | 30.15d? | 2006-06-02 | 2007-03-09 | 201d? | 245d | finish no earlier than 2007-03-09 | C4 | 1608h | 1366.8h | Mp-PROCc4 | Rel-7 | 23.333 | Chen Cheng, Huawei | h_hua@huawei.com | Kimmo |  |  |
| 116 | 20.4 | Stage 3 | 345d | 2006-02-13 A | 2007-06-08 | 55% | 155.25d | 2006-02-13 | 2007-06-08 | 345d | 180d | finish no earlier than 2007-06-08 | C4 | 2760h | 1518h | Mp-St3c4 | Rel-7 | 29.333 | Phil Hodges, Ericsson | philip.hodges@ericsson.com | Kimmo |  |  |
| 117 | 21 | IMS Stage 3 IETF Protocol alignment | 589d? | 2004-12-10 A | 2007-03-15 | 85% | 88.35d? | 2004-12-10 | 2007-03-15 | 589d? | 242d | finish no earlier than 2007-03-15 | C1 | 4712h | 4005.2h | IMSProtoc | Rel-7 | TR 24.930 |  |  |  |  |  |
| 118 | 22 | **Support of SMS over generic 3GPP IP access.** | 696d? | 2004-10-14 A | 2007-06-15 | 88% | 81.96d? | 2004-10-14 | 2007-06-15 | 696d? | 176d |  | S2 | 22192h | 14612.3h | SMSIP | Rel-7 | TR 23.abc, TS 23.abc | Wenlin Zhang (Huawei) | zhangwenlin@huawei.com | Maurice | TSG |  |
| 119 | 22.1 | FS on SMSIP | 173d? | 2004-10-14 A | 2005-06-13 A | 100% |  | 2004-10-14 | 2005-06-13 | 173d? |  | start no earlier than 2004-10-14 | S2 | 1384h | 1384h | SMSIP | Rel-7 | 23.804 |  |  |  |  |  |
| 120 | 22.2 | Stage 2 for SMSIP | 333d? | 2005-06-08 A | 2006-09-15 A | 100% |  | 2005-06-08 | 2006-09-15 | 333d? |  | finish no earlier than 2006-09-15 | S2 | 2664h | 2664h | SMSIP | Rel-7 | 23.204 |  |  |  |  |  |
| 121 | 22.3 | **Stage 3 for SMSIP** | 527d? | 2005-06-08 A | 2007-06-15 | 83% | 92.11d? | 2005-06-08 | 2007-06-15 | 527d? | 176d |  | C4 | 12576h | 9387.9h | SMSIP-St3 | Rel-7 |  | Jari Jansson, Nokia | jari.jansson@nokia.com |  |  |  |
| 122 | 22.3.1 | CT1 aspects for SMSIP | 527d? | 2005-06-08 A | 2007-06-15 | 85% | 79.05d? | 2005-06-08 | 2007-06-15 | 527d? | 176d | finish no earlier than 2007-06-15 | C1 | 4216h | 3583.6h | SMSIP | Rel-7 |  |  |  |  |  |  |
| 123 | 22.3.2 | CT4 aspects for SMSIP | 518d? | 2005-06-08 A | 2007-06-01 | 80% | 103.6d? | 2005-06-08 | 2007-06-01 | 518d? | 185d | finish no earlier than 2007-06-01 | C4 | 4144h | 3315.2h | SMSIP-St3-c4 | Rel-7 |  |  |  |  |  |  |
| 124 | 23 | **Evolution of Policy Control and Charging** | 697d? | 2004-10-14 A | 2007-06-15 | 84% | 114.18d? | 2004-10-14 | 2007-06-15 | 697d? | 175d |  | S2 | 26096h | 21318.5h | PCC | Rel-7 |  |  |  | Maurice | TSG |  |
| 125 | 23.1 | TR for PCC | 315d? | 2004-10-14 A | 2005-12-29 A | 100% |  | 2004-10-14 | 2005-12-29 | 315d? |  | finish no earlier than 2005-12-28 | S2 | 2520h | 2520h | PCC | Rel-7 |  |  |  |  |  |  |
| 126 | 23.2 | Stage 2 for PCC | 315d? | 2005-07-04 A | 2006-09-15 A | 100% |  | 2005-07-04 | 2006-09-15 | 315d? |  | finish no earlier than 2006-09-15 | S2 | 2520h | 2520h | PCC | Rel-7 | 23.203 |  |  |  |  |  |
| 127 | 23.3 | Evolution of policy control and flow based bearer level charging | 109d? | 2006-08-01 A | 2006-12-29 A | 100% |  | 2006-08-01 | 2006-12-29 | 109d? |  | start no earlier than 2006-08-01 | S2 | 872h | 872h | PCC | Rel-7 | 23.207, 23.125, 23.002, 23.228 | Balazs Bertenyi (Nokia) | balazs.bertenyi@nokia.com |  |  |  |
| 128 | 23.4 | SA5 Charging aspects of PCC | 316d? | 2006-03-31 A | 2007-06-15 | 80% | 63.2d? | 2006-03-31 | 2007-06-15 | 316d? | 175d | finish no earlier than 2007-06-15 | S5 | 2528h | 2022.4h | PCC-CH | Rel-7 | 32.250, 32.251, 32.298, 32.299 | Orange | alain.bibas@orange-ft.com | Adrian |  |  |
| 129 | 23.5 | Gx reference point for Policy and Charging Control | 376d? | 2005-12-02 A | 2007-05-11 | 85% | 56.4d? | 2005-12-02 | 2007-05-11 | 376d? | 200d | finish no earlier than 2007-05-11 | C3 | 3008h | 2556.8h | PCC-Gx | Rel-7 | 29.210, 29.207, 29.208 | Thomas Belling (Siemens) | thomas.belling@siemens.com | Seung Don |  |  |
| 130 | 23.6 | **Rx reference point for PCC CT3 aspects** | 401d? | 2005-12-02 A | 2007-06-15 | 68% | 128.51d? | 2005-12-02 | 2007-06-15 | 401d? | 175d |  | C3 | 9072h | 6164.75h | PCC-Rx | Rel-7 | 29.209, 29.211, 24.229 | Javier Pastor (Ericsson) | j.javier.pastor@ericsson.com | Seung Don |  |  |
| 131 | 23.6.1 | PCC-Rx CT3 aspects | 376d? | 2005-12-02 A | 2007-05-11 | 85% | 56.4d? | 2005-12-02 | 2007-05-11 | 376d? | 200d | finish no earlier than 2007-05-11 | C3 | 3008h | 2556.8h | PCC-Rx-c3 | Rel-7 | 29.209, 29.211, 24.229 | Javier Pastor (Ericsson) | j.javier.pastor@ericsson.com | Seung Don |  |  |
| 132 | 23.6.2 | PCC-Rx CT1 aspects | 357d? | 2005-12-02 A | 2007-06-15 | 50% | 178.5d? | 2005-12-02 | 2007-06-15 | 357d? | 175d | finish no earlier than 2007-06-15 | C1 | 2856h | 1428h | PCC-Rx-Gx-c1 | Rel-7 |  |  |  |  |  |  |
| 133 | 24 | Video Codec Performance Requirements | 634d? | 2005-01-03 A | 2007-06-07 | 75% | 158.5d? | 2005-01-03 | 2007-06-07 | 634d? | 181d | finish no earlier than 2007-06-07 | S4 | 5072h | 3804h | VICPer | Rel-7 | 26.234, 26.235, 26.346, 26.140 | Juergen Pandel (Siemens AG) | juergen.pandel@siemens.com | Paolo | TSG |  |
| 134 | 25 | DIAMETER on the GGSN Gi interface | 586d? | 2004-09-10 A | 2006-12-08 A | 100% |  | 2004-09-10 | 2006-12-08 | 586d? |  | finish no earlier than 2006-12-08 | C3 | 4688h | 4688h | DIAMGi | Rel-7 | 29.061 | Nico Gabriele (Vodafone) | Nico.Gabriele@vodafone.com | Seung Don | TSG |  |
| 135 | 26 | DIAMETER on the PDG Wi inteface | 586d? | 2004-09-10 A | 2006-12-08 A | 100% |  | 2004-09-10 | 2006-12-08 | 586d? |  | finish no earlier than 2006-12-08 | C3 | 4688h | 4688h | DIAMWi | Rel-7 | 29.161 | Nico Gabriele (Vodafone) | Nico.Gabriele@vodafone.com | Seung Don | TSG |  |

Notes:
- 110: 03/2006 SA#31 WID approved
- 111: WID approved SA#26. Record created after SA#27. It is about improved GERAN security
- 114: CT3 finally not involved in Mp interface definition (decided at CT#34)
- 116: indication in CT4#31 50%
- 117: TR 24.930: Signalling flows for the session setup in the IM CN subsystem based on Session Initiation Protocol (SIP)
- 118: Revised at SP#29
- 123: CT4#32: Stage 2 CR still outstanding....
- 127: Approved at SP#29. 23.125 will be discontinued from Release 7.
- 128: 03/2006 SA#31 WID approved
- 129: 08/03/2007 08:00
- 130: Approved at CP#30, Revised at CP#31, Revised at CP#33
- 131: 08/03/2007 08:00
- 134: 13/12/2005 08:00, Revised at CP#33
- 135: 13/12/2005 08:00, Revised at CP#33

| ID | WBS | Task | Type | Duration | Start | Finish | Complete | Remaining | Baseline start | Baseline finish | Baseline duration | Total slack | Constraint | Resources | Work | Actual work | Text1 | Text4 | Text5 | Text6 | Text7 | Text8 |
| --- | --- | --- | --- | --- | --- | --- | --- | --- | --- | --- | --- | --- | --- | --- | --- | --- | --- | --- | --- | --- | --- | --- |
| 136 | 27 | **CAMEL Trunk Triggers** |  | 251d? | 2004-12-17 A | 2005-12-05 A | 100% |  | 2004-12-17 | 2005-12-05 | 251d? |  |  | S1 | 6024h | 6024h | TTCAMEL | Amar Deol, Nortel Networks | deola@nortelnetworks.com | Rel-7 | TSG | Michael |
| 137 | 27.1 | Stage 1 for CAMEL Trunk Triggers |  | 251d? | 2004-12-17 A | 2005-12-05 A | 100% |  | 2004-12-17 | 2005-12-05 | 251d? |  |  | S1 | 2008h | 2008h | TTCAMEL | Amar Deol, Nortel Networks | deola@nortelnetworks.com | Rel-7 | TSG | Michael |
| 138 | 27.2 | CAMEL Trunk Originated Trigger Detection Points |  | 251d? | 2004-12-17 A | 2005-12-05 A | 100% |  | 2004-12-17 | 2005-12-05 | 251d? |  | start no earlier than 2004-12-17 | C4 | 2008h | 2008h | CamelR7 | David Hutton, Nortel Networks | dhutton@nortel.com | Rel-7 | TSG | Kimmo |
| 139 | 28 | MS Antenna Performance Evaluation Method and Requirements |  | 601d? | 2005-01-28 A | 2007-05-18 | 75% | 150.25d? | 2005-01-28 | 2007-05-18 | 601d? | 195d | finish no earlier than 2007-05-18 | G1 | 4808h | 3606h | APEMR | Ulf.Tegth (TeliaSonera) | Ulf.Tegth@teliasonera.com | Rel-7 | TSG | Paolo |
| 140 | 29 | **Lower 700 MHz Inclusion in the GERAN Specifications** |  | 390d? | 2005-01-03 A | 2006-06-30 A | 100% |  | 2005-01-03 | 2006-06-30 | 390d? |  |  | GP | 7632h | 7632h | GSM710 | Dave Cotton (UTC) | dcotton@mtview.union-tel.com | Rel-7 | TSG | Paolo |
| 141 | 29.1 | Inclusion of the 698 – 746 MHz band into GERAN core specifications |  | 129d? | 2005-01-03 A | 2005-06-30 A | 100% |  | 2005-01-03 | 2005-06-30 | 129d? |  | finish no earlier than 2005-06-30 | G1 | 1032h | 1032h | GSM710-core |  |  | Rel-7 |  | Paolo |
| 142 | 29.2 | G1 aspects of GSM710 |  | 217.5d? | 2005-08-31 A | 2006-06-30 A | 100% |  | 2005-08-31 | 2006-06-30 | 217.5d? |  | finish no earlier than 2006-06-30 | G1 | 1740h | 1740h | GSM-710-test |  |  | Rel-7 |  | Paolo |
| 143 | 29.3 | G3 aspects of GSM710 |  | 217.5d? | 2005-08-31 A | 2006-06-30 A | 100% |  | 2005-08-31 | 2006-06-30 | 217.5d? |  | finish no earlier than 2006-06-30 | G3 | 1740h | 1740h | GSM-710-test |  |  | Rel-7 |  | Stoyan |
| 144 | 30 | **Enhancements of VGCS for public authority officials** |  | 731d? | 2004-08-27 A | 2007-06-15 | 99% | 6.01d? | 2004-08-27 | 2007-06-15 | 731d? | 175d |  | S1 | 25920h | 19879.5h | EVGCS | Siemens |  | Rel-7 | TSG | Andrijana |
| 145 | 30.1 | Stage 1 | milestone | 0d? | 2004-08-27 A | 2004-08-27 A | 100% |  | 2004-08-27 | 2004-08-27 | 0d? |  | finish no earlier than 2004-08-27 | S1 |  |  | EVGCS | Joerg Swetina (Siemens AG) | joerg.swetina@SIEMENS.COM | Rel-7 | TSG | Michael |
| 146 | 30.2 | **Architecture and protocol aspects** |  | 731d? | 2004-08-27 A | 2007-06-15 | 99% | 9.44d? | 2004-08-27 | 2007-06-15 | 731d? | 175d |  | C1 | 14904h | 14711.5h | EVGCS | Robert Zaus (Siemens) |  | Rel-7 |  |  |
| 147 | 30.2.1 | CT1 aspects of EVGCS |  | 731d? | 2004-08-27 A | 2007-06-15 | 98% | 14.62d? | 2004-08-27 | 2007-06-15 | 731d? | 175d | finish no earlier than 2006-09-15 | C1 | 5848h | 5731.04h | EVGCS | Siemens |  | Rel-7 |  |  |
| 148 | 30.2.2 | CT4 aspects of EVGCS |  | 401d? | 2004-08-27 A | 2006-03-10 A | 100% |  | 2004-08-27 | 2006-03-10 | 401d? |  | finish no earlier than 2006-03-10 | C4 | 3208h | 3208h | EVGCS-St23-c4 | Siemens |  | Rel-7 |  |  |
| 149 | 30.3 | GERAN2 aspects |  | 646d? | 2004-08-27 A | 2007-02-16 A | 100% |  | 2004-08-27 | 2007-02-16 | 646d? |  | finish no earlier than 2007-02-16 | G2 | 5168h | 5168h | EVGCS | Ken Isaacs (Siemens) | kenneth.isaacs@roke.co.uk | Rel-7 | TSG | Gert |
| 150 | 31 | **Improvements of VGCS for parallel use of services** |  | 523d? | 2005-03-15 A | 2007-03-15 | 99% | 0d? | 2005-03-15 | 2007-03-15 | 523d? | 0d |  | S1 | 12230.2h | 8552h | IVGCS |  |  | Rel-7 |  |  |
| 151 | 31.1 | Service Requirements for VGCS improvements |  | 62d? | 2005-03-15 A | 2005-06-08 A | 100% |  | 2005-03-15 | 2005-06-08 | 62d? |  | finish no earlier than 2005-06-08 | S1 | 496h | 496h | IVGCS | Kurt Bischinger (T-Mobile) | kurt.bischinger@t-mobile.at | Rel-7 | TSG | Michael |
| 152 | 31.2 | Stage 2 modifications for VGCS improvements |  | 335d? | 2005-12-01 A | 2007-03-14 A | 100% |  | 2005-12-01 | 2007-03-14 | 335d? |  | start no earlier than 2005-12-01 | C1 | 2680h | 2680h | IVGCS | Kurt Bischinger (T-Mobile) | kurt.bischinger@t-mobile.at | Rel-7 | TSG |  |
| 153 | 31.3 | **Protocol aspects** |  | 336d? | 2005-12-01 A | 2007-03-15 A | 100% |  | 2005-12-01 | 2007-03-15 | 336d? |  |  | C1 | 5376h | 5376h | IVGCS | Dieter Jacobsohn (T-Mobile) |  | Rel-7 |  |  |
| 154 | 31.3.1 | CT1 aspects of IVGCS |  | 336d? | 2005-12-01 A | 2007-03-15 A | 100% |  | 2005-12-01 | 2007-03-15 | 336d? |  | finish no earlier than 2007-03-15 | C1 | 2688h | 2688h | IVGCS | T-Mobile |  | Rel-7 |  |  |
| 155 | 31.3.2 | Deleted - CT4 aspects of IVGCS | milestone | 0d? | 2007-03-09 A | 2007-03-09 A | 100% |  | 2007-03-09 | 2007-03-09 | 0d? |  | finish no earlier than 2007-03-09 | C4 |  |  | IVGCS-St3-c4 | T-mobile |  | Rel-7 |  |  |
| 156 | 32 | **OSA Rel-7** |  | 584d? | 2005-03-15 A | 2007-06-09 | 98% | 13.86d? | 2005-03-15 | 2007-06-09 | 584d? | 180d |  | S1 | 17920h | 15319.5h | OSA7 | Eamonn Murray (AePONA) | eamonn.murray@aepona.com | Rel-7 | TSG | Michael |
| 157 | 32.1 | Service Requirements for OSA Service Broker |  | 62d? | 2005-03-15 A | 2005-06-08 A | 100% |  | 2005-03-15 | 2005-06-08 | 62d? |  | finish no earlier than 2005-06-08 | S1 | 496h | 496h | OSA7-SB | Eamonn Murray (AePONA) | eamonn.murray@aepona.com | Rel-7 | TSG | Michael |
| 158 | 32.2 | Stage 2 OSA API Service Brokering |  | 156d? | 2006-04-28 A | 2006-12-01 A | 100% |  | 2006-04-28 | 2006-12-01 | 156d? |  |  | C5 | 1248h | 1248h | OSA7-SB | AePONA | damian.oneill@aepona.com | Rel-7 | TSG | Adrian |
| 159 | 32.3 | Stage 3 OSA API Service Brokering |  | 156d? | 2006-04-28 A | 2006-12-01 A | 100% |  | 2006-04-28 | 2006-12-01 | 156d? |  | finish no earlier than 2006-12-01 | C5 | 1248h | 1248h | OSA7-SB | AePONA | damian.oneill@aepona.com | Rel-7 |  |  |

Notes:
- 137: Text3: 22.078
- 138: Not started
- 139: Started / Text3: 25.9xx, 45.005
- 140: Text3: 24.008, 43.022, 44.018, 44.118, 45, 001, 45.005, 51.010, 51.021
- 141: Completed / Text3: 24.008, 43.022, 44.018, 44.118, 45, 001, 45.005,
- 142: Text3: 51.021
- 143: Text3: 51.010
- 144: Text3: 43.068, 44.068, 24.008, 29.002
- 145: Text3: 42.068, 43.068
- 146: Text3: 43.068, 44.068
- 147: Text3: 43.068, 44.068, 24.008
- 148: Text3: 29.002
- 151: "completeed" as from Chris S' e-mail / Text3: 42.068
- 152: Updated by CT1 chair / Text3: 43.068
- 153: Previous name (before CT32) was Architecture and protocol aspects / Text3: 44.068
- 154: end date updated by CT1-chairman after CT#33 / Text3: 43.068, 44.068
- 155: CT4#33 stage 2 solution is still open. ... / Text3: 29.002
- 157: az: WID URL corrected / Text3: 22.127
- 158: Text3: 23.198
- 159: Text3: 29.198-16

| ID | WBS | Task | Type | Duration | Start | Finish | Complete | Remaining | Baseline start | Baseline finish | Baseline duration | Total slack | Constraint | Resources | Work | Actual work | Text1 | Text3 | Text4 | Text5 | Text6 | Text8 | Text7 | Text10 |
| --- | --- | --- | --- | --- | --- | --- | --- | --- | --- | --- | --- | --- | --- | --- | --- | --- | --- | --- | --- | --- | --- | --- | --- | --- |
| 160 | 32.4 | **OSA Stage 2/3 enhancements** |  | 291d? | 2006-04-28 A | 2007-06-09 | 97% | 9.51d? | 2006-04-28 | 2007-06-09 | 291d? | 180d |  | C5 | 10256h | 7766.4h | OSA7 | 29.198/9, 23.198 | AePONA | damian.oneill@aepona.com | Rel-7 | Adrian |  |  |
| 161 | 32.4.1 | Parlay X Message Broadcast Web Service |  | 156d? | 2006-04-28 A | 2006-12-01 A | 100% |  | 2006-04-28 | 2006-12-01 | 156d? |  | finish no earlier than 2006-12-01 | C5 | 1248h | 1248h | OSA7 | 29.199-15, 23.198 | ETRI |  | Rel-7 |  |  |  |
| 162 | 32.4.2 | Parlay X Geocoding Web Service |  | 156d? | 2006-04-28 A | 2006-12-01 A | 100% |  | 2006-04-28 | 2006-12-01 | 156d? |  | finish no earlier than 2006-12-01 | C5 | 1248h | 1248h | OSA7 | 29.199-16, 23.198 | ETRI |  | Rel-7 |  |  |  |
| 163 | 32.4.3 | Parlay X Application driven QoS Web Service |  | 226d? | 2006-04-28 A | 2007-03-09 A | 100% |  | 2006-04-28 | 2007-03-09 | 226d? |  | finish no earlier than 2007-03-09 | C5 | 1808h | 1808h | OSA7 | 29.199-17, 23.198 | BT |  | Rel-7 |  |  |  |
| 164 | 32.4.4 | Parlay-X Device Management Web Service |  | 162d? | 2006-10-26 A | 2007-06-09 | 80% | 32.4d? | 2006-10-26 | 2007-06-09 | 162d? | 180d | finish no earlier than 2007-06-09 | C5 | 1296h | 1036.8h | OSA7 | 29.199-18, 23.198 | Telenor |  | Rel-7 |  |  |  |
| 165 | 32.4.5 | Parlay-X Multimedia Streaming Session Management Web Service |  | 97d? | 2006-10-26 A | 2007-03-09 A | 100% |  | 2006-10-26 | 2007-03-09 | 97d? |  | start no earlier than 2006-10-26 | C5 | 776h | 776h | OSA7 | 29.199-19, 23.198 | Telenor |  | Rel-7 |  |  |  |
| 166 | 32.4.6 | Parlay-X Multimedia Multicast Control Web Service |  | 97d? | 2006-10-26 A | 2007-03-09 A | 100% |  | 2006-10-26 | 2007-03-09 | 97d? |  | start no earlier than 2006-10-26 | C5 | 776h | 776h | OSA7 | 29.199-20, 23.198 | ETRI |  | Rel-7 |  |  |  |
| 167 | 32.4.7 | OSA API Conference Call Control SCF |  | 97d? | 2006-10-26 A | 2007-03-09 A | 100% |  | 2006-10-26 | 2007-03-09 | 97d? |  | start no earlier than 2006-10-26 | C5 | 776h | 776h | OSA7 | 29.198-04-5, 23.198 | Ericsson |  | Rel-7 |  |  |  |
| 168 | 33 | Dynamic and Interactive Multimedia Scenes |  | 583d? | 2005-03-15 A | 2007-06-07 | 70% | 174.9d? | 2005-03-15 | 2007-06-07 | 583d? | 181d | finish no earlier than 2007-06-07 | S4 | 4664h | 3264.8h | DIMS | 26.140, 26.142, 26.234, 26.244, 23.346 | Gaëlle MARTIN-COCHER (Streamezzo) | gaelle.martin-cocher@streamezzo.com | Rel-7 | Paolo | TSG |  |
| 169 | 34 | Liberty Alliance and 3GPP Security Interworking |  | 451d? | 2005-03-10 A | 2006-11-30 | 98% | 9.02d? | 2005-03-10 | 2006-11-30 | 451d? | 316d | finish no earlier than 2006-11-30 | S3 | 3608h | 3535.84h | LibSec | 33.980 | Silke Holtmanns, Nokia | Silke.Holtmanns@NOKIA.COM | Rel-7 | Maurice | TSG |  |
| 170 | 35 | **WLAN-UMTS Interworking Phase 2** |  | 371d? | 2004-01-05 A | 2005-06-07 A | 100% |  | 2004-01-05 | 2005-06-07 | 371d? |  |  | S1 | 3888h | 3888h | WLAN2 |  | Fredric Paint, Telenor | frederic.paint@telenor.com | Rel-7 | Michael | TSG |  |
| 171 | 35.1 | Stage 1 on Session Continuity |  | 115d? | 2004-01-05 A | 2004-06-11 A | 100% |  | 2004-01-05 | 2004-06-11 | 115d? |  | start no earlier than 2004-01-05 | S1 | 920h | 920h | WLAN-SC |  |  |  | Rel-7 |  |  | SP-24 |
| 172 | 35.2 | Stage 2 on Session Continuity: covered by SAE | milestone | 0d? | 2005-06-07 A | 2005-06-07 A | 100% |  | 2005-06-07 | 2005-06-07 | 0d? |  | finish no earlier than 2005-06-07 | S2 |  |  |  |  |  |  | Rel-7 |  |  |  |
| 173 | 36 | **WLAN Interworking – Private Network access from WLAN 3GPP IP Access** |  | 252d? | 2005-10-10 A | 2006-09-26 A | 100% |  | 2005-10-10 | 2006-09-26 | 252d? |  |  | S2 | 6920h | 6920h | WLANPNA |  |  |  | Rel-7 | Maurice |  |  |
| 174 | 36.1 | WLAN-PNA - Stage 2 |  | 185d? | 2005-10-10 A | 2006-06-23 A | 100% |  | 2005-10-10 | 2006-06-23 | 185d? |  | start no earlier than 2005-10-10 | S2 | 1480h | 1480h | WLANPNA-st2 | 23.234, 33.234 | Toshiyuki Tamura (NEC) | tamurato@aj.jp.nec.com | Rel-7 | Maurice |  |  |
| 175 | 36.2 | **WLAN-PNA - Stage 3** |  | 170d? | 2006-02-01 A | 2006-09-26 A | 100% |  | 2006-02-01 | 2006-09-26 | 170d? |  |  | C1 | 5440h | 5440h | WLANPNA-st3 |  | Pierre-Jean Muller (NEC) | pierre-jean.muller@nectech.fr | Rel-7 | Andrijana | TSG |  |
| 176 | 36.2.1 | CT1 aspets for WLAN-PNA |  | 170d? | 2006-02-01 A | 2006-09-26 A | 100% |  | 2006-02-01 | 2006-09-26 | 170d? |  | start no earlier than 2006-02-01 | C1 | 1360h | 1360h | WLANPNA-st3 | 24.234 | Pierre-Jean Muller (NEC) | pierre-jean.muller@nectech.fr | Rel-7 | Andrijana |  |  |
| 177 | 36.2.2 | CT3 aspets for WLAN-PNA |  | 170d? | 2006-02-01 A | 2006-09-26 A | 100% |  | 2006-02-01 | 2006-09-26 | 170d? |  | start no earlier than 2006-02-01 | C3 | 1360h | 1360h | WLANPNA-st3 | 29.161 | Pierre-Jean Muller (NEC) | pierre-jean.muller@nectech.fr | Rel-7 | Andrijana |  |  |
| 178 | 36.2.3 | CT4 aspets for WLAN-PNA |  | 170d? | 2006-02-01 A | 2006-09-26 A | 100% |  | 2006-02-01 | 2006-09-26 | 170d? |  | start no earlier than 2006-02-01 | C4 | 1360h | 1360h | WLANPNA-st3 | 29.234 | Pierre-Jean Muller (NEC) | pierre-jean.muller@nectech.fr | Rel-7 | Andrijana |  |  |
| 179 | 37 | **Enhancements to support QoS provisioning over 3GPP/WLAN Interworking** |  | 520d? | 2005-03-14 A | 2007-03-09 A | 100% |  | 2005-03-14 | 2007-03-09 | 520d? |  |  | S2 | 8360h | 8360h | WLANQOS | 23.836 | Osok Song, Samsung | osok.song@samsung.com | Rel-7 | Maurice |  |  |
| 180 | 37.1 | TR on support of QoS on WLAN |  | 232d? | 2005-03-14 A | 2006-01-31 A | 100% |  | 2005-03-14 | 2006-01-31 | 232d? |  | start no earlier than 2005-03-14 | S2 | 1856h | 1856h | WLANQOS |  |  |  | Rel-7 |  |  |  |
| 181 | 37.2 | Stage 2 on support of QoS over 3GPP/WLAN interworking |  | 108d? | 2006-02-01 A | 2006-06-30 A | 100% |  | 2006-02-01 | 2006-06-30 | 108d? |  | start no earlier than 2006-02-01 | S2 | 864h | 864h | WLANQOS |  |  |  | Rel-7 |  |  |  |
| 182 | 37.3 | Stage 3 CT1 on support of QoS over 3GPP/WLAN Interworking |  | 64d? | 2006-09-04 A | 2006-11-30 A | 100% |  | 2006-09-04 | 2006-11-30 | 64d? |  | finish no earlier than 2006-11-30 | C1 | 512h | 512h | WLANQOS |  |  |  | Rel-7 |  |  |  |
| 183 | 37.4 | Stage 3 CT4 on support of QoS over 3GPP/WLAN Interworking |  | 121d? | 2006-09-22 A | 2007-03-09 A | 100% |  | 2006-09-22 | 2007-03-09 | 121d? |  | finish no earlier than 2007-03-09 | C4 | 968h | 968h | WLAN-QOS | 24.234, 29.234, 23.008 | Peng Zhang, Huawei | zhang.peng@huawei.com | Rel-7 |  |  |  |

Notes:
- 160: CT#34: WID updated. Completion 12/06 =>03/07
- 169: WID approved SA#27.
- 170: Created at TSG#27 by A. Sultan because of WLAN items belonging to Rel-7
- 173: Placeholder created to Hold SA2 and CT1 BBs
- 174: Approved at SP#29
- 175: Approved at CP#29
- 176: Approved at CP#29
- 177: Approved at CP#29
- 178: CT4#31; no impacts identified, therefor completed
- 179: Moved from FS section Feb 06
- 182: Line added according to e-mail from Atle
- 183: WID was approved at CT#32...

| ID | WBS | Task | Type | Duration | Start | Finish | Complete | Remaining | Baseline start | Baseline finish | Baseline duration | Total slack | Constraint | Resources | Work | Actual work | Text1 | Text4 | Text5 | Text6 | Text8 | Text7 |
| --- | --- | --- | --- | --- | --- | --- | --- | --- | --- | --- | --- | --- | --- | --- | --- | --- | --- | --- | --- | --- | --- | --- |
| 184 | 38 | **Voice call continuity between CS and IMS (incl. I-WLAN)** |  | 641d? | 2004-12-31 A | 2007-06-15 | 95% | 33.27d? | 2004-12-31 | 2007-06-15 | 641d? | 175d |  | S2 | 20216h | 15149.8h | VCC | Andy Bennett, Lucent; Roger Bunting, Cingular | andybennett@Alcatel-Lucent.com | Rel-7 | Maurice |  |
| 185 | 38.1 | TR for VCC |  | 245d? | 2004-12-31 A | 2005-12-08 A | 100% |  | 2004-12-31 | 2005-12-08 | 245d? |  | finish no earlier than 2005-12-08 | S2 | 1960h | 1960h | VCC |  |  | Rel-7 |  |  |
| 186 | 38.2 | Stage 1 for VCC |  | 140d? | 2005-03-17 A | 2005-09-28 A | 100% |  | 2005-03-17 | 2005-09-28 | 140d? |  | finish no earlier than 2005-09-28 | S1 | 1120h | 1120h | VCC |  |  | Rel-7 | Mike |  |
| 187 | 38.3 | Stage 2 for VCC |  | 264d? | 2005-09-06 A | 2006-09-08 A | 100% |  | 2005-09-06 | 2006-09-08 | 264d? |  | finish no earlier than 2006-09-08 | S2 | 2112h | 2112h | VCC |  |  | Rel-7 |  |  |
| 188 | 38.4 | **Stage 3 for VCC** |  | 358d? | 2006-02-01 A | 2007-06-15 | 97% | 9.25d? | 2006-02-01 | 2007-06-15 | 358d? | 175d |  | C1 | 7296h | 7107.41h | VCC | Keith Drage (Alcatel-Lucent) | drage@alcatel-lucent.com | Rel-7 |  |  |
| 189 | 38.4.1 | CT1 aspects of VCC |  | 358d? | 2006-02-01 A | 2007-06-15 | 96% | 14.32d? | 2006-02-01 | 2007-06-15 | 358d? | 175d | finish no earlier than 2007-06-15 | C1 | 2864h | 2749.44h | VCC | Keith Drage (Alcatel-Lucent) | drage@alcatel-lucent.com | Rel-7 | Andrijana |  |
| 190 | 38.4.2 | CT4 aspects of VCC |  | 196d? | 2006-06-09 A | 2007-03-09 A | 100% |  | 2006-06-09 | 2007-03-09 | 196d? |  | start no earlier than 2006-06-09 | C4 | 1568h | 1568h | VCC-St3-c4 | Keith Drage Alcatel- (Lucent) | drage@alcatel-ucent.com | Rel-7 | Kimmo |  |
| 191 | 38.4.3 | Deleted - CT3 aspects of VCC | milestone | 0d? | 2006-11-02 A | 2006-11-02 A | 100% |  | 2006-11-02 | 2006-11-02 | 0d? |  | finish no earlier than 2006-11-02 | C3 |  |  | VCC | Keith Drage (Lucent) | drage@lucent.com | Rel-7 |  |  |
| 192 | 38.5 | SA5 Charging aspects of VCC |  | 325d? | 2006-03-17 A | 2007-06-14 | 80% | 65d? | 2006-03-17 | 2007-06-14 | 325d? | 176d | finish no earlier than 2007-06-14 | S5 | 2600h | 2080h | VCC-CH | Orange | alain.bibas@orange-ft.com | Rel-7 | Adrian |  |
| 193 | 39 | **OAM&P** |  | 870d? | 2004-02-16 A | 2007-06-15 | 84% | 141.68d? | 2004-02-16 | 2007-06-15 | 870d? | 175d |  | S5 | 95985.1h | 67746.2h | OAM7 | Toche | Christian.Toche@huawei.com | Rel-7 | Adrian | TSG |
| 194 | 39.1 | **Network Infrastructure Management** |  | 465d? | 2005-09-02 A | 2007-06-14 | 93% | 31.8d? | 2005-09-02 | 2007-06-14 | 465d? | 176d |  | S5 | 41800h | 35476h | OAM7-NIM |  |  | Rel-7 |  |  |
| 195 | 39.1.1 | Enhance NRM to accommodate NGN (IMS as basis of the Next Generation Network) |  | 465d? | 2005-09-02 A | 2007-06-14 | 80% | 93d? | 2005-09-02 | 2007-06-14 | 465d? | 176d | finish no earlier than 2007-06-14 | S5 | 3720h | 2976h | OAM7-NIM | Motorola |  | Rel-7 |  |  |
| 196 | 39.1.2 | Co-operative Element Management interface (CO-OP) (Study + Implementation) |  | 400d? | 2005-09-02 A | 2007-03-15 A | 100% |  | 2005-09-02 | 2007-03-15 | 400d? |  | finish no earlier than 2007-03-15 | S5 | 3200h | 3200h | OAM7-NIM | Motorola |  | Rel-7 |  |  |
| 197 | 39.1.3 | Network Management (NM) Itf-N performance criteria |  | 465d? | 2005-09-02 A | 2007-06-14 | 90% | 46.5d? | 2005-09-02 | 2007-06-14 | 465d? | 176d | finish no earlier than 2007-06-14 | S5 | 3720h | 3348h | OAM7-NIM | China Mobile |  | Rel-7 |  |  |
| 198 | 39.1.4 | Delta synchronization between IRP Manager and IRP Agent (Study + Implementation) |  | 465d? | 2005-09-02 A | 2007-06-14 | 80% | 93d? | 2005-09-02 | 2007-06-14 | 465d? | 176d | finish no earlier than 2007-06-14 | S5 | 3720h | 2976h | OAM7-NIM | Siemens |  | Rel-7 |  |  |
| 199 | 39.1.5 | Subscription Management (SuM) IRP Solution Sets |  | 330d? | 2005-09-02 A | 2006-12-07 A | 100% |  | 2005-09-02 | 2006-12-07 | 330d? |  | finish no earlier than 2006-12-07 | S5 | 2640h | 2640h | OAM7-NIM | Ericsson |  | Rel-7 |  |  |
| 200 | 39.1.6 | Integration Reference Point (IRP) Security Management |  | 400d? | 2005-09-02 A | 2007-03-15 A | 100% |  | 2005-09-02 | 2007-03-15 | 400d? |  | finish no earlier than 2007-03-15 | S5 | 3200h | 3200h | OAM7-NIM | Huawei |  | Rel-7 |  |  |
| 201 | 39.1.7 | Partial suspension of Itf-N during maintenance/testing (Study + Implementation) |  | 465d? | 2005-09-02 A | 2007-06-14 | 90% | 46.5d? | 2005-09-02 | 2007-06-14 | 465d? | 176d | finish no earlier than 2007-06-14 | S5 | 3720h | 3348h | OAM7-NIM | Siemens |  | Rel-7 |  |  |
| 202 | 39.1.8 | Stopped - Management of Legacy Equipment |  | 336d? | 2005-09-02 A | 2006-12-15 A | 100% |  | 2005-09-02 | 2006-12-15 | 336d? |  | finish no earlier than 2006-12-15 | S5 | 2688h | 2688h | OAM7-NIM | Siemens |  | Rel-7 |  |  |
| 203 | 39.1.9 | Stopped - Rules for Vendor Specific Extensions |  | 400d? | 2005-09-02 A | 2007-03-15 A | 100% |  | 2005-09-02 | 2007-03-15 | 400d? |  | finish no earlier than 2007-03-15 | S5 | 3200h | 3200h | OAM7-NIM | Siemens |  | Rel-7 |  |  |
| 204 | 39.1.10 | Backward and Forward Compatibility of IRP systems |  | 465d? | 2005-09-02 A | 2007-06-14 | 90% | 46.5d? | 2005-09-02 | 2007-06-14 | 465d? | 176d | finish no earlier than 2007-06-14 | S5 | 3720h | 3348h | OAM7-NIM | Ericsson |  | Rel-7 |  |  |
| 205 | 39.1.11 | Repeater Network Resource Model (NRM) definition |  | 214d? | 2006-02-13 A | 2006-12-07 A | 100% |  | 2006-02-13 | 2006-12-07 | 214d? |  | finish no earlier than 2006-12-07 | S5 | 1712h | 1712h | OAM7-NIM | China Mobile |  | Rel-7 |  |  |
| 206 | 39.1.12 | UTRAN radio channel power monitoring |  | 284d? | 2006-02-13 A | 2007-03-15 A | 100% |  | 2006-02-13 | 2007-03-15 | 284d? |  | finish no earlier than 2007-03-15 | S5 | 2272h | 2272h | OAM7-NIM | China Mobile |  | Rel-7 |  |  |
| 207 | 39.1.13 | Notification XML Schema |  | 71d? | 2006-12-07 A | 2007-03-15 A | 100% |  | 2006-12-07 | 2007-03-15 | 71d? |  | finish no earlier than 2007-03-15 | S5 | 568h | 568h | OAM7-NIM | Huawei |  | Rel-7 |  |  |

Notes:
- 184: WID approved SA#27. Revised at SA#28. WID update approved at SA#32 / Text3: 22.101, 23.228, 32.250, 32.260, 32.299, 32.298
- 185: Text3: 23.806
- 187: Text3: 23.206
- 188: Text3: new TS, 24.229, 23.008, 23.009, 23.078, 29.078, 29.163, 29.228, 29.229, 29.230, 29.278, 29.328, 29.329
- 189: Text3: new TS, 24.206 and 24.216
- 190: Text3: 23.003
- 191: Text3: 29.163
- 192: 03/2006 SA#31 WID approved / Text3: 32.250, 32.260, 32.298, 32.299
- 195: Text3: 32.731/2/3/5, 32.631/2/3/5
- 196: Text3: TR 32.806/814, 32.101
- 197: Text3: TR 32.811
- 198: Text3: new TR 32.8xy, new TSs 32.111-n,32.60n; For n = 1 to 5
- 199: Text3: 32.307/317/607/667/665, 32.101, 32.175
- 200: Text3: 32.372/3/5, 32.111,32.30x,32.32x,32.33x,32.34x,32.35x,32.36x,32.41x,32.60x,32.61x,32.66x
- 201: Text3: 32.381/2/3
- 202: Text3: new TS 32.xxx
- 203: Request to TSG#35 to STOP the WI / Text3: 32.62n; For n = 1 to 5
- 204: Submit Exception Sheet for TSG#35 Approval / Text3: new TS 32.15X
- 205: Text3: 32.721/2/3/5
- 206: Text3: 32.405, 32.64n; For n = 1 to 5
- 207: 12/2006 SA#34 WID approved / Text3: New TS 32.325/345/365/415, CR to 32.335/615/665

| ID | WBS | Task | Type | Duration | Start | Finish | Complete | Remaining | Baseline start | Baseline finish | Baseline duration | Total slack | Constraint | Resources | Work | Actual work | Text1 | Text6 | Text4 | Text7 | Text12 | Text5 | Text8 |
| --- | --- | --- | --- | --- | --- | --- | --- | --- | --- | --- | --- | --- | --- | --- | --- | --- | --- | --- | --- | --- | --- | --- | --- |
| 208 | 39.2 | **Performance Management** |  | 465d? | 2005-09-02 A | 2007-06-14 | 92% | 37.03d? | 2005-09-02 | 2007-06-14 | 465d? | 176d |  | S5 | 22992h | 17737.2h | OAM7-PM | Rel-7 |  |  |  |  |  |
| 209 | 39.2.1 | Performance measurements definition for CN CS |  | 400d? | 2005-09-02 A | 2007-03-15 A | 100% |  | 2005-09-02 | 2007-03-15 | 400d? |  | finish no earlier than 2007-03-15 | S5 | 3200h | 3200h | OAM7-PM | Rel-7 | China Mobile |  |  |  |  |
| 210 | 39.2.2 | Enhancement UTRAN performance measurements definition |  | 465d? | 2005-09-02 A | 2007-06-14 | 85% | 69.75d? | 2005-09-02 | 2007-06-14 | 465d? | 176d | finish no earlier than 2007-06-14 | S5 | 3720h | 3162h | OAM7-PM | Rel-7 | China Mobile |  |  |  |  |
| 211 | 39.2.3 | Add TDD specific counters in Performance measurement |  | 330d? | 2005-09-02 A | 2006-12-07 A | 100% |  | 2005-09-02 | 2006-12-07 | 330d? |  | finish no earlier than 2006-12-15 | S5 | 2640h | 2640h | OAM7-PM | Rel-7 | CATT |  |  |  |  |
| 212 | 39.2.4 | ATM bearer network Performance measurements |  | 400d? | 2005-09-02 A | 2007-03-15 A | 100% |  | 2005-09-02 | 2007-03-15 | 400d? |  | finish no earlier than 2007-03-15 | S5 | 3200h | 3200h | OAM7-PM | Rel-7 | ZTE |  |  |  |  |
| 213 | 39.2.5 | Performance measurements definition for IMS |  | 465d? | 2005-09-02 A | 2007-06-14 | 85% | 69.75d? | 2005-09-02 | 2007-06-14 | 465d? | 176d | finish no earlier than 2007-06-14 | S5 | 3720h | 3162h | OAM7-PM | Rel-7 | China Mobile |  |  |  |  |
| 214 | 39.2.6 | HSDPA performance measurements |  | 349d? | 2006-02-13 A | 2007-06-14 | 85% | 52.35d? | 2006-02-13 | 2007-06-14 | 349d? | 176d | finish no earlier than 2007-06-14 | S5 | 2792h | 2373.2h | OAM7-PM | Rel-7 | China Mobile |  |  |  |  |
| 215 | 44.5 | **Trace Management** |  | 870d? | 2004-02-16 A | 2007-06-15 | 56% | 382.97d? | 2004-02-16 | 2007-06-15 | 870d? | 175d |  | S5 | 24233.1h | 10741h | OAM7-Trace | Rel-7 | Vodafone | TSG |  |  |  |
| 216 | 39.3.1 | End-to-end Service Level tracing for IMS |  | 350d? | 2005-11-11 A | 2007-03-15 A | 100% |  | 2005-11-11 | 2007-03-15 | 350d? |  | finish no earlier than 2007-03-15 | S5 | 2800h | 2800h | OAM7-Trace | Rel-7 | Vodafone | TSG | SP-31 |  |  |
| 217 | 39.3.2 | Trace record content for UTRAN TDD |  | 330d? | 2005-09-02 A | 2006-12-07 A | 100% |  | 2005-09-02 | 2006-12-07 | 330d? |  | finish no earlier than 2006-12-07 | S5 | 2640h | 2640h | OAM7-Trace | Rel-7 | Nokia | TSG |  |  |  |
| 218 | 39.3.3 | IRP for Subscriber and Equipment Trace Management |  | 465d? | 2005-09-02 A | 2007-06-14 | 60% | 186d? | 2005-09-02 | 2007-06-14 | 465d? | 176d | finish no earlier than 2007-06-14 | S5 | 3720h | 2232h | OAM7-Trace | Rel-7 | Nokia | TSG |  |  |  |
| 219 | 39.3.4 | Deleted - SIP enhancements for trace |  | 863.14d? | 2004-02-16 A | 2007-06-15 | 2% | 845.88d? | 2004-02-16 | 2007-06-15 | 863.14d? | 175d | finish no earlier than 2007-06-15 | C1 | 6905.12h | 138.1h | OAM7-Trace | Rel-7 |  |  | CP-32 |  |  |
| 220 | 39.3.5 | Deleted - duplicated with UID 35063 - IRP for Subscriber and Equipment Trace Management |  | 336d? | 2005-09-02 A | 2006-12-15 A | 100% |  | 2005-09-02 | 2006-12-15 | 336d? |  | finish no earlier than 2006-12-15 | S5 | 2688h | 2688h | OAM7-Trace | Rel-7 | Nokia | TSG | SP-33 |  |  |
| 221 | 40 | Trust Requirements for Open Platforms in 3GPP |  | 499d? | 2005-01-03 A | 2006-11-30 | 70% | 149.7d? | 2005-01-03 | 2006-11-30 | 499d? | 316d | finish no earlier than 2006-11-30 | S3 | 3992h | 2794.4h | TrustOP | Rel-7 | Silke Holtmanns, Nokia | TSG |  | Silke.Holtmanns@NOKIA.COM | Michael |
| 222 | 41 | Development of UEA2 and UIA2 |  | 268d? | 2004-12-01 A | 2005-12-09 | 80% | 53.6d? | 2004-12-01 | 2005-12-09 | 268d? | 570d | finish no earlier than 2005-12-09 | S3 | 2144h | 1715.2h | AlgUEA2 | Rel-7 | Per Christoffersson, Teliasonera | TSG |  | per.christoffersson@teliasonera.com | Michael |
| 223 | 42 | Lawful Interception in the 3GPP Rel-7 architecture |  | 118d? | 2005-06-28 A | 2005-12-08 | 75% | 29.5d? | 2005-06-28 | 2005-12-08 | 118d? | 571d | start no earlier than 2005-06-28 | S3 | 944h | 708h | LI-7A | Rel-7 | Berthold Wilhelm, BMWI |  |  | berthold.wilhelm@regtp.de | Mike |
| 224 | 43 | **Support of Conversational Services in A/Gb mode via the PS domain** |  | 551d? | 2005-04-08 A | 2007-05-18 | 82% | 100.78d? | 2005-04-08 | 2007-05-18 | 551d? | 195d |  | GP | 13642.8h | 7928.77h | SCSAGB | Rel-7 | Gunnar Hedby, Ericsson |  |  | gunnar.hedby@ericsson.com | Paolo |
| 225 | 43.1 | Minimise the transfer delay between the SGSN and the MS |  | 529.95d? | 2005-04-08 A | 2007-05-18 | 80% | 105.99d? | 2005-04-08 | 2007-05-18 | 529.95d? | 195d | finish no earlier than 2007-05-18 | GP | 4239.6h | 3391.68h | SCSAGB-MTD | Rel-7 |  |  |  |  | Paolo |
| 226 | 43.2 | Definition of radio resource management functionality |  | 551d? | 2005-04-08 A | 2007-05-18 | 80% | 110.2d? | 2005-04-08 | 2007-05-18 | 551d? | 195d | finish no earlier than 2007-05-18 | G1 | 4408h | 3526.4h | SCSAGB-RRM | Rel-7 | Gunnar Hedby, Ericsson |  |  | gunnar.hedby@ericsson.com | Paolo |
| 227 | 43.3 | Support of Conversational Services in A/Gb mode via the PS domain – RLC Non-Persistent mode |  | 101d? | 2006-06-30 A | 2006-11-17 A | 100% |  | 2006-06-30 | 2006-11-17 | 101d? |  | finish no earlier than 2006-11-17 | G2 | 808h | 808h | SCSAGB-RLCNP | Rel-7 | Gunnar Hedby, Ericsson |  |  | gunnar.hedby@ericsson.com | Gert |
| 228 | 43.4 | Deleted- Radio Channel Support | milestone | 0d? | 2006-07-17 A | 2006-07-17 A | 100% |  | 2006-07-17 | 2006-07-17 | 0d? |  | start no earlier than 2006-07-17 | G2 |  |  | SCSAGB-RCHS | Rel-7 | Gunnar Hedby, Ericsson |  | SP-32 | gunnar.hedby@ericsson.com | Gert |
| 229 | 43.5 | Deleted- Modifications to FLO | milestone | 0d? | 2006-07-17 A | 2006-07-17 A | 100% |  | 2006-07-17 | 2006-07-17 | 0d? |  | start no earlier than 2006-07-17 | G2 |  |  | SCSAGB-FLO | Rel-7 | Gunnar Hedby, Ericsson |  | SP-32 | gunnar.hedby@ericsson.com | Gert |
| 230 | 44 | **Addition of new frequency band to GSM (T-GSM810)** |  | 551d? | 2005-04-08 A | 2007-05-18 | 89% | 60.52d? | 2005-04-08 | 2007-05-18 | 551d? | 195d |  | GP | 10912h | 5789.6h | TGSM810 | Rel-7 | Chen De, Huawei |  |  | chende@huawei.com | Paolo |
| 231 | 44.1 | Changes to core specification |  | 106d? | 2005-04-08 A | 2005-09-02 A | 100% |  | 2005-04-08 | 2005-09-02 | 106d? |  | finish no earlier than 2005-09-02 | GP | 848h | 848h | TGSM810-Core | Rel-7 | Chen De, Huawei |  |  | chende@huawei.com | Paolo |
| 232 | 44.2 | Changes to MS testing specification |  | 551d? | 2005-04-08 A | 2007-05-18 | 84% | 89.3d? | 2005-04-08 | 2007-05-18 | 551d? | 195d | finish no earlier than 2007-05-18 | G3 | 4408h | 3693.6h | TGSM810-MStest | Rel-7 | Chen De, Huawei |  |  | chende@huawei.com | Stoyan |
| 233 | 44.3 | Changes to BTS testing specification |  | 156d? | 2005-04-08 A | 2005-11-11 A | 100% |  | 2005-04-08 | 2005-11-11 | 156d? |  | finish no earlier than 2005-11-11 | G1 | 1248h | 1248h | TGSM810-BTStest | Rel-7 | Chen De, Huawei |  |  | chende@huawei.com | Paolo |

Notes:
- 209: Text3: 32.407, 32.408
- 210: Submit Exception Sheet for TSG#35 Approval / Text3: 32.405
- 211: Text3: 32.405
- 212: Text3: No impact on 32.404, 32.405, 32.406, 32.407
- 213: Submit Exception Sheet for TSG#35 Approval / Text3: 32.404,32.409,32.437, 32.632/3/4/5
- 214: Submit Exception Sheet for TSG#35 Approval / Text3: 32.405
- 216: 07/2005: OMA (Stage 1), Stage 2/3 SA5, CT1/3/4 / Text3: CR 32.101, 32.421/2/3.
- 217: Text3: CR 32.421/2/3.
- 218: Submit Exception Sheet for TSG#35 Approval / Text3: 32.421,32.422,32.423. 3 new TS 32.441, 32.442, 32.443
- 219: combined with UID 11067
- 220: Text3: 32.421,32.422,32.423. 3 new TS 32.4x1,2,3
- 221: WID approved SA#26. Record created after SA#27 / Text3: 33.905
- 222: WID approved SA#26, Dependant on Funding Availability. Record created after SA#27 / Text3: 35.919, 35.215, 35.216, 35.217, 35.218
- 223: Text3: 33.106, 33.107, 33.108
- 224: Originally started Nov. 2003 as GP-030443
- 227: Text3: 43.955, 43.064, 44.060, 45.001, 45.002, 45.003, 45.005, 45.010, 51.010, 51.021
- 230: Text3: 45.005, 45.050, 24.008, 45.008, 45.001, 43.022, 43.030, 44.018, 44.060, 51.010-1, 51.021
- 231: Text3: 45.005, 45.050, 24.008, 45.008, 45.001, 43.022, 43.030, 44.018, 44.060
- 232: Started / Text3: 51010-1
- 233: Text3: 51021

| ID | WBS | Task | Type | Duration | Start | Finish | Complete | Remaining | Baseline start | Baseline finish | Baseline duration | Total slack | Constraint | Resources | Work | Actual work | Text1 | Text4 | Text5 | Text6 | Text8 | Text3 | Text7 | Text12 |
| --- | --- | --- | --- | --- | --- | --- | --- | --- | --- | --- | --- | --- | --- | --- | --- | --- | --- | --- | --- | --- | --- | --- | --- | --- |
| 234 | 45 | **Handover of dedicated and shared resources while in dual transfer mode** |  | 421d? | 2005-04-08 A | 2006-11-17 A | 100% |  | 2005-04-08 | 2006-11-17 | 421d? |  |  | GP | 12672h | 12672h | HODSRDTM | Rami Vaittinen, Nokia | rami.vaittinen@nokia.com | Rel-7 | Paolo |  |  |  |
| 235 | 45.1 | Handover of dedicated and shared resources while in dual transfer mode |  | 321d? | 2005-04-08 A | 2006-06-30 A | 100% |  | 2005-04-08 | 2006-06-30 | 321d? |  | finish no earlier than 2006-06-30 | G2 | 2568h | 2568h | HODSRDTM-G2 | Rami Vaittinen, Nokia | rami.vaittinen@nokia.com | Rel-7 | Gert | 43.055, 44.018, 44.060 |  |  |
| 236 | 45.2 | MS Conformance Testing |  | 421d? | 2005-04-08 A | 2006-11-17 A | 100% |  | 2005-04-08 | 2006-11-17 | 421d? |  | finish no earlier than 2006-11-17 | G3 | 3368h | 3368h | HODSRDTM-Mstest | Rami Vaittinen, Nokia | rami.vaittinen@nokia.com | Rel-7 | Stoyan | 51-010 |  |  |
| 237 | 45.3 | BTS conformance testing |  | 421d? | 2005-04-08 A | 2006-11-17 A | 100% |  | 2005-04-08 | 2006-11-17 | 421d? |  | finish no earlier than 2006-11-17 | G1 | 3368h | 3368h | HODSRDTM-BTStest | Rami Vaittinen, Nokia | rami.vaittinen@nokia.com | Rel-7 | Paolo | 51.026 |  |  |
| 238 | 46 | Future GERAN Evolution |  | 486d? | 2005-04-08 A | 2007-02-16 A | 100% |  | 2005-04-08 | 2007-02-16 | 486d? |  | finish no earlier than 2007-02-16 | GP | 3888h | 3888h | FGE | Eddie Riddington, Nokia Corporation | eddie.riddington@nokia.com | Rel-7 | Paolo | 45.912 |  |  |
| 239 | 47 | 3G-324M Video Telephony Call Setup Times Improvements |  | 341d? | 2005-06-08 A | 2006-09-27 A | 100% |  | 2005-06-08 | 2006-09-27 | 341d? |  | finish no earlier than 2006-09-27 | S4 | 2728h | 2728h | VTCSTI | Edward Hall (Vodafone) | edward.hall@vodafone.co.uk | Rel-7 | Paolo | 26.911 |  |  |
| 240 | 48 | **Identification of Communication Services in IMS** |  | 554d? | 2005-05-02 A | 2007-06-14 | 54% | 255.22d? | 2005-05-02 | 2007-06-14 | 554d? | 176d |  | S2 | 11960h | 4188h | ServID | Stephen Terrill, Ericsson | stephen.terrill@ericsson.com | Rel-7 | Maurice | 22.228, 23.228, 23.203, 32.260, 32.298, 32.299 |  |  |
| 241 | 48.1 | TR for ICS |  | 232d? | 2005-05-02 A | 2006-03-21 A | 100% |  | 2005-05-02 | 2006-03-21 | 232d? |  | finish no earlier than 2006-03-20 | S2 | 1856h | 1856h | ServID |  |  | Rel-7 |  | 23.816 |  |  |
| 242 | 48.2 | Stage 2 of ICS |  | 144d? | 2005-11-11 A | 2006-05-31 A | 100% |  | 2005-11-11 | 2006-05-31 | 144d? |  | start no earlier than 2005-11-11 | S2 | 1152h | 1152h | ServID |  |  | Rel-7 |  |  |  |  |
| 243 | 48.3 | Stage 3 of ICS |  | 250d? | 2006-03-31 A | 2007-03-15 | 40% | 150d? | 2006-03-31 | 2007-03-15 | 250d? | 241d | finish no earlier than 2007-03-15 | C1 | 2000h | 800h | ServID | Christer Holmberg (Ericsson) | christer.holmberg@ericsson.com | Rel-7 | Andrijana |  |  |  |
| 244 | 48.4 | SA5 Charging aspects of ServID |  | 315d? | 2006-03-31 A | 2007-06-14 | 10% | 283.5d? | 2006-03-31 | 2007-06-14 | 315d? | 176d | finish no earlier than 2007-06-14 | S5 | 2520h | 252h | ServID | Orange | alain.bibas@orange-ft.com | Rel-7 | Adrian | 32.260, 32.298, 32.299 |  |  |
| 245 | 49 | **VoIMS bearer related enhancements** |  | 354d? | 2005-03-15 A | 2006-07-21 | 99% | 0d? | 2005-03-15 | 2006-07-21 | 354d? | 0d |  | S2 | 4303.2h | 1576h | VoIMS |  |  | Rel-7 |  |  |  |  |
| 246 | 49.1 | Improved support of IMS Realtime Services using HSDPA/HSUPA |  | 197d? | 2005-03-15 A | 2005-12-14 A | 100% |  | 2005-03-15 | 2005-12-14 | 197d? |  | start no earlier than 2005-03-15 | R2 | 1576h | 1576h | RANimp-IMSRealTime | Don Zelmer | don.zelmer@CINGULAR.COM | Rel-7 | MCC_RAN |  | TSG |  |
| 247 | 49.2 | Deleted - FS on enhancement of radio performance for VoIMS | milestone | 0d? | 2006-07-21 A | 2006-07-21 A | 100% |  | 2006-07-21 | 2006-07-21 | 0d? |  | start no earlier than 2006-07-21 | S2 |  |  | VoIMS | Laurence Lautier, Nortel Networks | lautierl@nortel.com | Rel-7 | Maurice | 23.807 |  | SP-32 |
| 248 | 50 | Performance Characterization of VoIMS over HSDPA\EUL channels |  | 658d? | 2005-03-15 A | 2007-09-20 | 60% | 263.2d? | 2005-03-15 | 2007-09-20 | 658d? | 106d | finish no earlier than 2007-09-20 | S4 | 5264h | 3158.4h | VoIMS-PCVoIMS | James W. McGowan (Alcatel-Lucent) | mcgowan@alcatel-lucent.com | Rel-7 | Paolo | 26.935 | TSG |  |
| 249 | 51 | **Optimizations for Multimedia Telephony over IMS** |  | 0d? | 2005-09-28 A | 2005-09-28 A | 100% |  | 2005-09-28 | 2005-09-28 | 0d? |  |  | S4 |  |  | OMTIMS | Olle Franceschi (Ericsson) | olle.franceschi@ericsson.com | Rel-7 | Paolo | 26.235, 26.236 |  |  |
| 250 | 51.1 | Stopped (deleted) - Characterisation of Adaptive Jitter Management Performance for VoIP Services | milestone | 0d? | 2005-09-28 A | 2005-09-28 A | 100% |  | 2005-09-28 | 2005-09-28 | 0d? |  | start no earlier than 2007-03-15 | S4 |  |  | OMTIMS-CAJMP | David Huo (Lucent Technologies) | dhuo@lucent.com | Rel-7 | Paolo |  |  |  |
| 251 | 52 | End-to-End Multimedia Services Performance Metrics |  | 382d? | 2005-09-28 A | 2007-03-15 A | 100% |  | 2005-09-28 | 2007-03-15 | 382d? |  | finish no earlier than 2007-03-15 | S4 | 3056h | 3056h | E2EMSPM | Zhang Yan (China Mobile) | zhangyanyf@chinamobile.com | Rel-7 | Paolo | 26.944 |  |  |
| 252 | 53 | **Supporting Globally Routable User Agent URIs in IMS** |  | 415d? | 2005-11-14 A | 2007-06-15 | 99% | 4.05d? | 2005-11-14 | 2007-06-15 | 415d? | 175d |  | S2 | 5600h | 4396.64h | GRUU | Adrian Buckley (Research In Motion) | abuckley@rim.com | Rel-7 | Maurice | 23.8XX, 22.228, 23.228, 23.218, 24.229 |  |  |
| 253 | 53.1 | TR on GRUU |  | 219d? | 2005-11-14 A | 2006-09-14 A | 100% |  | 2005-11-14 | 2006-09-14 | 219d? |  | finish no earlier than 2006-09-14 | S2 | 1752h | 1752h | GRUU |  |  | Rel-7 | Maurice |  |  |  |
| 254 | 53.2 | Stage 2 of GRUU |  | 65d? | 2006-07-03 A | 2006-09-29 A | 100% |  | 2006-07-03 | 2006-09-29 | 65d? |  | start no earlier than 2006-07-03 | S2 | 520h | 520h | GRUU |  |  | Rel-7 | Maurice |  |  |  |
| 255 | 53.3 | Stage 3 of GRUU |  | 271d? | 2006-06-02 A | 2007-06-15 | 98% | 5.42d? | 2006-06-02 | 2007-06-15 | 271d? | 175d | finish no earlier than 2007-06-15 | C1 | 2168h | 2124.64h | GRUU | Bernie McKibben, CableLabs |  | Rel-7 | Andrijana |  |  |  |
| 256 | 54 | ISIM API for Java Card |  | 200d? | 2005-03-14 A | 2005-12-16 | 90% | 20d? | 2005-03-14 | 2005-12-16 | 200d? | 565d | finish no earlier than 2005-12-16 | C6 | 1600h | 1440h | APIJAVA | Sebastian Hans, Sun Microsystems Ltd. |  | Rel-7 | Gaby | 31.103, TS 102 241 |  |  |
| 257 | 55 | NDS Authentication Framework Extension for TLS |  | 50d? | 2006-09-28 A | 2006-12-06 | 99% | 0.5d? | 2006-09-28 | 2006-12-06 | 50d? | 312d | finish no earlier than 2006-09-28 | S3 | 400h | 396h | NDSAFTLS | Tiina Koskinen (Nokia) | tiina.s.koskinen@nokia.com | Rel-7 | Michael | 33.310 |  |  |

Notes:
- 234: Started at GERAN#24
- 235: Started at GERAN#24
- 236: Stopped, no work done
- 237: Stopped, no work done
- 240: WID approved SA#28. Updated WID approved SA#32
- 243: end date updated by CT1-chairman after CT#33
- 244: 03/2006 SA#31 WID approved
- 245: Created by MCC to group all VoIMS related items, after consultation of chairs
- 247: WID approved SA#28: SA2#52: CLOSED - To be removed from the work plan
- 249: Completed
- 250: Stopped at SA#35
- 252: Approved at SP#29
- 253: Abandomned
- 254: S2#52: "GURU" corrected to "GRUU"
- 255: S2#52: "GURU" corrected to "GRUU"

| ID | WBS | Task | Duration | Start | Finish | Complete | Remaining | Baseline start | Baseline finish | Baseline duration | Total slack | Constraint | Resources | Work | Actual work | Text1 | Text6 | Text4 | Text5 | Text8 | Text7 |
| --- | --- | --- | --- | --- | --- | --- | --- | --- | --- | --- | --- | --- | --- | --- | --- | --- | --- | --- | --- | --- | --- |
| 258 | 56 | **Rel7 Security enhancements** | 319d? | 2005-09-12 A | 2006-11-30 | 95% | 16.76d? | 2005-09-12 | 2006-11-30 | 319d? | 316d |  | S3 | 9336h | 7798.68h | SEC7 | Rel-7 |  |  |  |  |
| 259 | 56.1 | HTTPS connection between a UICC and a NAF | 1d? | 2005-09-12 A | 2005-09-12 A | 100% |  | 2005-09-12 | 2005-09-12 | 1d? |  | start no earlier than 2005-09-12 | S3 | 8h | 8h | SEC7-HSUN | Rel-7 | Jacques Seif (Gemalto) | JSeif@axalto.com |  |  |
| 260 | 56.2 | 2G GBA: 2G SIM usage in 3GPP GAA framework | 61d? | 2005-09-12 A | 2005-12-05 A | 100% |  | 2005-09-12 | 2005-12-05 | 61d? |  | finish no earlier than 2005-12-05 | S3 | 488h | 488h | SEC7-2GGBA | Rel-7 | Silke Holtmanns (Nokia) | Silke.Holtmanns@nokia.com |  |  |
| 261 | 56.3 | Generic Authentication Architecture usage extensions and optimisations | 319d? | 2005-09-12 A | 2006-11-30 | 90% | 31.9d? | 2005-09-12 | 2006-11-30 | 319d? | 316d | finish no earlier than 2006-11-30 | S3 | 2552h | 2296.8h | GAA2 | Rel-7 | Silke Holtmanns (Nokia) | Silke.Holtmanns@nokia.com |  |  |
| 262 | 56.4 | **SS7 TCAP security Gateway** | 241d? | 2005-09-12 A | 2006-08-14 | 99% | 0d? | 2005-09-12 | 2006-08-14 | 241d? | 0d |  | S3 | 3736h | 2588h | SEC7-NDS-TCAPsec | Rel-7 | Marc Blommaert (Siemens) | marc.blommaert@siemens.com |  |  |
| 263 | 56.4.1 | SA3 aspects of SEC7-NDS-TCAPsec | 130d? | 2005-09-12 A | 2006-03-10 A | 100% |  | 2005-09-12 | 2006-03-10 | 130d? |  | finish no earlier than 2006-03-10 | S3 | 1040h | 1040h | SEC7-NDS-TCAPsec-SA3 | Rel-7 | Marc Blommaert (Siemens) | marc.blommaert@siemens.com |  |  |
| 264 | 56.4.2 | TCAPsec Gateway | 96d? | 2006-04-03 A | 2006-08-14 A | 100% |  | 2006-04-03 | 2006-08-14 | 96d? |  | start no earlier than 2006-04-01 | C4 | 768h | 768h | SEC7-NDS-TCAPsec-CT4 | Rel-7 | Ulrich Wiehe, Siemens | Ulrich.wiehe@gksag.de | Kimmo |  |
| 265 | 57 | Key establishment between a UICC and a terminal | 201.45d? | 2005-12-07 A | 2006-09-28 | 70% | 60.44d? | 2005-12-07 | 2006-09-28 | 201.45d? | 361d | finish no earlier than 2006-09-28 | S3 | 1611.6h | 1128.12h | KeyEstUTerm | Rel-7 | Mireille Pauliac (Gemalto) | mireille.pauliac@gemplus.com |  |  |
| 266 | 58 | **Mobile Station Receive Diversity (DARP Phase II)** | 471d? | 2005-11-11 A | 2007-08-31 | 69% | 143.95d? | 2005-11-11 | 2007-08-31 | 471d? | 120d |  | GP | 15480h | 8355.7h | MSRD2 | Rel-7 | Kent Pedersen, Nokia Corporation (ETSI) | kent.pedersen@nokia.com | Paolo |  |
| 267 | 58.1 | Performance Requirements for Mobile Station Receive Diversity, DARP Phase II | 331d? | 2005-11-11 A | 2007-02-16 A | 100% |  | 2005-11-11 | 2007-02-16 | 331d? |  | finish no earlier than 2007-02-16 | GP | 2648h | 2648h | MSRD2-PerfReq | Rel-7 | Kent Pedersen, Nokia Corporation (ETSI) | kent.pedersen@nokia.com | Paolo |  |
| 268 | 58.2 | Capability signalling of Mobile Station Receive Diversity, DARP Phase II | 331d? | 2005-11-11 A | 2007-02-16 A | 100% |  | 2005-11-11 | 2007-02-16 | 331d? |  | finish no earlier than 2007-02-16 | GP | 2648h | 2648h | MSRD2-CapSig | Rel-7 | Kent Pedersen, Nokia Corporation (ETSI) | kent.pedersen@nokia.com | Paolo, Gert |  |
| 269 | 58.3 | Test Scenarios for Mobile Station Receive Diversity, DARP Phase II | 331d? | 2005-11-11 A | 2007-02-16 A | 100% |  | 2005-11-11 | 2007-02-16 | 331d? |  | finish no earlier than 2007-02-16 | GP | 2648h | 2648h | MSRD2-TestSc | Rel-7 | Kent Pedersen, Nokia Corporation (ETSI) | kent.pedersen@nokia.com | Paolo |  |
| 270 | 58.4 | MS conformance test of DARP Phase II (MSRD) | 471d? | 2005-11-11 A | 2007-08-31 | 5% | 447.45d? | 2005-11-11 | 2007-08-31 | 471d? | 120d | finish no earlier than 2007-08-31 | GP | 3768h | 188.4h | MSRD2-Msconf | Rel-7 | Kent Pedersen, Nokia Corporation (ETSI) | kent.pedersen@nokia.com | Paolo, Stoyan |  |
| 271 | 59 | **MBMS Enhancements** | 566d? | 2005-07-11 A | 2007-09-10 | 60% | 227.63d? | 2005-07-11 | 2007-09-10 | 566d? | 114d |  | S1 | 9212.64h | 3454.57h | MBMSE | Rel-7 | Liu Hong, China Mobile | liuhongyfw@chinamobile.com | Mike |  |
| 272 | 59.1 | Stage 1 of MBMSE | 109d? | 2005-07-11 A | 2005-12-08 | 80% | 21.8d? | 2005-07-11 | 2005-12-08 | 109d? | 571d | finish no earlier than 2005-12-08 | S1 | 872h | 697.6h | MBMSE | Rel-7 | Liu Hong, China Mobile | liuhongyfw@chinamobile.com | Mike |  |
| 273 | 59.2 | MBMS FDD Physical layer Enhancements | 117.29d? | 2006-12-15 A | 2007-06-04 | 61% | 46d? | 2006-12-15 | 2007-06-04 | 117.29d? | 184d | finish no earlier than 2007-06-04 | R1 | 938.32h | 570.32h | MBMSE-RANPhysFDD | Rel-7 | Lars Lindbom | Lars.Lindbom@ericsson.com |  |  |
| 274 | 59.3 | MBMS TDD Physical layer Enhancements | 117.29d? | 2006-12-15 A | 2007-06-04 | 80% | 23.46d? | 2006-12-15 | 2007-06-04 | 117.29d? | 184d | finish no earlier than 2007-06-04 | R1 | 938.32h | 750.65h | MBMSE-RANPhysTDD | Rel-7 | Nicholas Anderson |  |  |  |
| 275 | 59.4 | MBMS Low Chip Rate TDD Physical Layer Enhancement | 127d? | 2007-03-16 | 2007-09-10 |  |  | 2007-03-16 | 2007-09-10 | 127d? | 114d | finish no earlier than 2007-09-10 | R1 | 1016h |  | MBMSE-RANPhysLCRTDD | Rel-7 |  |  |  |  |
| 276 | 59.5 | MBMS Mz interface | 115d? | 2006-12-04 A | 2007-05-11 | 85% | 17.25d? | 2006-12-04 | 2007-05-11 | 115d? | 200d | finish no earlier than 2007-05-11 | C3 | 920h | 782h | MBMSMz | Rel-7 | Deng Tingting, Huawei | ttdeng@huawei.com | Seung Don |  |
| 277 | 60 | MBMS User Service Extensions | 392d? | 2005-12-07 A | 2007-06-07 | 50% | 196d? | 2005-12-07 | 2007-06-07 | 392d? | 181d | finish no earlier than 2007-06-07 | S4 | 3136h | 1568h | MBMSUSE | Rel-7 | Thorsten Lohmar (Ericsson) | Thorsten.Lohmar@ericsson.com | Paolo |  |
| 278 | 61 | IMS Support of Conferencing and Messaging Group Management | 355d? | 2005-11-04 A | 2007-03-15 A | 100% |  | 2005-11-04 | 2007-03-15 | 355d? |  | finish no earlier than 2007-03-15 | C1 | 2840h | 2840h | IMSconf | Rel-7 | Keith Drage (Alcatel-Lucent) | drage@alcatel-lucent.com | Andrijana |  |
| 279 | 62 | **Selective Disabling of UE Capabilities** | 624.36d? | 2005-01-24 A | 2007-06-15 | 98% | 11.24d? | 2005-01-24 | 2007-06-15 | 624.36d? | 175d |  | S1 | 12036.8h | 11820.2h | SDoUE | Rel-7 | Nigel Barnes (Motorola Ltd) | Nigel.Barnes@motorola.com | Michael | TSG |
| 280 | 62.1 | Stage 1 of SDoUE | 393.6d? | 2005-01-24 A | 2006-12-08 A | 100% |  | 2005-01-24 | 2006-12-08 | 393.6d? |  | finish no earlier than 2006-12-08 | S1 | 3148.8h | 3148.8h | SDoUE-CRs | Rel-7 | Nigel Barnes (Motorola Ltd) | Nigel.Barnes@motorola.com | Michael | TSG |
| 281 | 62.2 | TR on different possible architectures | 195d? | 2005-03-21 A | 2005-12-16 A | 100% |  | 2005-03-21 | 2005-12-16 | 195d? |  | finish no earlier than 2005-12-16 | S2 | 1560h | 1560h | SDoUE-FS | Rel-7 |  |  | Maurice |  |
| 282 | 62.3 | Stage 3 of SDoUE | 331d? | 2006-03-10 A | 2007-06-15 | 95% | 16.55d? | 2006-03-10 | 2007-06-15 | 331d? | 175d | finish no earlier than 2007-06-15 | C1 | 2648h | 2515.6h | SDoUE | Rel-7 | Christian Herrero (Ericsson) | christian.herrero@ericsson.com | Andrijana |  |
| 283 | 63 | Key establishment between a UICC hosting device and a remote device | 235d? | 2006-12-06 A | 2007-10-30 | 20% | 188d? | 2006-12-06 | 2007-10-30 | 235d? | 78d | finish no earlier than 2007-10-30 | S3 | 1880h | 376h | PNM | Rel-7 | Vesa Lehtovirta (Ericsson) | Vesa.Lehtovirta@ericsson.com | Michael |  |
| 284 | 64 | Study of Personal Network and Personal Area Network | 167d? | 2005-07-11 A | 2006-02-28 A | 100% |  | 2005-07-11 | 2006-02-28 | 167d? |  | start no earlier than 2005-07-11 | S1 | 1336h | 1336h | PNPAN | Rel-7 |  |  |  |  |

Notes:
- 259: Text3: 33.222, 24.109, 33.918
- 260: Text3: 33.220, 33.920
- 261: Text3: 33.220, 29.109, 24.109, 33.223, (33.223 goes to R8)
- 262: Text3: 33.200, 33.204
- 263: Text3: 33.200, 33.204
- 264: Study WI... / Text3: new TS 29.204
- 265: Text3: 33.110
- 266: Started / Text3: 24.008, 45.005, 51.010
- 267: Text3: 45.005
- 268: Text3: 24.008
- 269: Text3: 45.005
- 270: Text3: 51.010
- 272: Strucutre created by MCC to include RAN aspects under SA1 Feature
- 273: Text3: 25.211, 25.212, 25.213, 25.101, 25.104, 25.331, 25.433, 25.346, 25.306
- 274: Text3: 25.346, 25.221, 25.222, 25.223, 25.224, 25.306, 25.331, 25.402, 25.433, 25.102, 25.105, 25.123
- 276: 08/03/2007 08:00 / Text3: 29.061
- 277: Text3: 26.346, 26.946
- 278: Text3: 24.147, 24.229
- 279: Moved from FS section Feb 06 / Text3: 22.xxx
- 280: Moved from FS section Feb 06 / Text3: 22.011, 22.060, 23.060, 24.008, 23.805, 24.305
- 281: Moved from FS section Feb 06 / Text3: 23.805
- 282: Text3: New TS 24.305
- 283: Text3: 33.259
- 284: Moved from FS section Feb 06

| ID | WBS | Task | Duration | Start | Finish | Complete | Remaining | Baseline start | Baseline finish | Baseline duration | Total slack | Constraint | Resources | Work | Actual work | Text1 | Text4 | Text5 | Text6 | Text8 | Text7 |
| --- | --- | --- | --- | --- | --- | --- | --- | --- | --- | --- | --- | --- | --- | --- | --- | --- | --- | --- | --- | --- | --- |
| 285 | 65 | **Multimedia Telephony Service for IMS** | 330d? | 2006-03-10 A | 2007-06-15 | 71% | 94.41d? | 2006-03-10 | 2007-06-15 | 330d? | 176d |  | S1 | 8880h | 6339.61h | MTSI | Supporting Companies: | peter.bleckert @ericsson.com | Rel-7 | Mike |  |
| 286 | 65.1 | Stage 1 of MTSI | 191d? | 2006-03-15 | 2006-12-06 |  |  | 2006-03-15 | 2006-12-06 | 191d? | 312d | start no earlier than 2006-03-15 | S1 | 1528h |  | MTSI-REQ |  | peter.bleckert @ericsson.com | Rel-7 | Mike |  |
| 287 | 65.2 | Stage 3 of MTSI | 330d? | 2006-03-10 A | 2007-06-15 | 90% | 33d? | 2006-03-10 | 2007-06-15 | 330d? | 176d | finish no earlier than 2007-06-15 | C1 | 2640h | 2376h | MTSI | Christer Holmberg (Ericsson) | christer.holmberg@ericsson.com | Rel-7 | Andrijana |  |
| 288 | 65.3 | Media handling and interaction in MTSI | 262d? | 2006-03-15 A | 2007-03-15 A | 100% |  | 2006-03-15 | 2007-03-15 | 262d? |  | finish no earlier than 2007-03-15 | S4 | 2096h | 2096h |  |  | olle.franceschi@ericsson.com | Rel-7 | Paolo |  |
| 289 | 66 | **Multimedia interworking between IMS and CS networks** | 426d? | 2005-09-23 A | 2007-05-11 | 87% | 57.31d? | 2005-09-23 | 2007-05-11 | 426d? | 200d |  | C3 | 7207.99h | 3332.23h | MIWIMS | Nico Gabriele, Vodafone UK | nico.gabriele@vodafone.com | Rel-7 | Seung Don |  |
| 290 | 66.1 | Note: Stages 1 and 2 defined in earlier Release | 49d? | 2005-09-23 A | 2005-11-30 A | 100% |  | 2005-09-23 | 2005-11-30 | 49d? |  | start no earlier than 2005-09-23 | S2 | 392h | 392h |  |  |  | Rel-7 |  |  |
| 291 | 66.2 | Stage 3 of MW-IMS | 426d? | 2005-09-23 A | 2007-05-11 | 85% | 63.9d? | 2005-09-23 | 2007-05-11 | 426d? | 200d | finish no earlier than 2007-05-11 | C3 | 3408h | 2896.8h | MWIMS-St3 |  |  | Rel-7 |  |  |
| 292 | 67 | **Network selection enhancements** | 328d? | 2006-03-15 A | 2007-06-15 | 90% | 32.8d? | 2006-03-15 | 2007-06-15 | 328d? | 175d |  | S1 | 6320h | 3970.4h | NSP-CR | Chris Friel, O2 | chris.friel@o2.com | Rel-7 | Michael |  |
| 293 | 67.1 | Stage 1 of NSP | 191d? | 2006-03-15 A | 2006-12-06 | 90% | 19.1d? | 2006-03-15 | 2006-12-06 | 191d? | 312d | start no earlier than 2006-03-15 | S1 | 1528h | 1375.2h | NSP-TS | Chris Friel, O2 | chris.friel@o2.com | Rel-7 | Michael |  |
| 294 | 67.2 | Procedural aspects of NSP | 271d? | 2006-06-02 A | 2007-06-15 | 90% | 27.1d? | 2006-06-02 | 2007-06-15 | 271d? | 175d | finish no earlier than 2007-06-15 | C1 | 2168h | 1951.2h | NSP-CR | Andrew Howell (Motorola) | andrew.howell@motorola.com | Rel-7 | Andrijana |  |
| 295 | 68 | **Interoperability between VGCS/VBS and A/Gb flexibility** | 253d? | 2006-03-22 A | 2007-03-09 A | 100% |  | 2006-03-22 | 2007-03-09 | 253d? |  |  | C1 | 5320h | 5320h | VGCSFlex | Robert Zaus (Siemens) | robert.zaus@siemens.com | Rel-7 | Andrijana |  |
| 296 | 68.1 | CT1 aspects of VGCSFlex | 159d? | 2006-03-22 A | 2006-10-30 A | 100% |  | 2006-03-22 | 2006-10-30 | 159d? |  | finish no earlier than 2006-10-30 | C1 | 1272h | 1272h | VGCSFlex |  |  | Rel-7 |  |  |
| 297 | 68.2 | CT4 aspects of VGCSFlex | 253d? | 2006-03-22 A | 2007-03-09 A | 100% |  | 2006-03-22 | 2007-03-09 | 253d? |  | finish no earlier than 2007-03-09 | C4 | 2024h | 2024h | VGCSFlex-c4 |  |  | Rel-7 |  |  |
| 298 | 69 | **One Tunnel solution for Optimisation of Packet Data Traffic** | 418d? | 2006-03-27 A | 2007-10-31 | 44% | 232.27d? | 2006-03-27 | 2007-10-31 | 418d? | 77d |  | S2 | 7048h | 3131.56h | OPTUNEL | Antti Pasanen (Nokia) |  | Rel-7 | Maurice |  |
| 299 | 69.1 | Discontinued - Stage 2 Study for One Tunnel solution | 125d? | 2006-03-27 A | 2006-09-15 A | 100% |  | 2006-03-27 | 2006-09-15 | 125d? |  | finish no earlier than 2005-09-12 | S2 | 1000h | 1000h | OPTUNEL-Study | Antti Pasanen (Nokia) | antti.j.pasanen@nokia.com | Rel-7 | Maurice | TSG |
| 300 | 69.2 | One Tunnel Deployment Guideline | 268d? | 2006-10-23 A | 2007-10-31 | 4% | 257.28d? | 2006-10-23 | 2007-10-31 | 268d? | 77d | finish no earlier than 2007-10-31 | S2 | 2144h | 85.76h | OPTUNEL-Guide | Lan Liu (Huawei) | lan.liu@huawei.com | Rel-7 | Maurice | TSG |
| 301 | 69.3 | Stage 2 specification for One Tunnel solution | 70d? | 2006-09-11 A | 2006-12-15 A | 100% |  | 2006-09-11 | 2006-12-15 | 70d? |  | finish no earlier than 2006-12-15 | S2 | 560h | 560h | OPTUNEL-Stage2 | Antti Pasanen (Nokia) | antti.j.pasanen@nokia.com | Rel-7 | Maurice | TSG |
| 302 | 70 | **Downlink Dual Carrier** | 421d? | 2006-01-20 A | 2007-08-31 | 46% | 228.56d? | 2006-01-20 | 2007-08-31 | 421d? | 120d |  | GP | 11540.8h | 3419.2h | GDCDL | Leonardo Provvedi, Siemens AG | leonardo.provvedi@roke.co.uk | Rel-7 | Paolo |  |
| 303 | 70.1 | Downlink Dual Carrier Stage 2 | 116d? | 2006-01-20 A | 2006-06-30 A | 100% |  | 2006-01-20 | 2006-06-30 | 116d? |  | finish no earlier than 2006-06-30 | G1 | 928h | 928h | GDCDL-Stage2 | Leonardo Provvedi, Siemens AG | leonardo.provvedi@roke.co.uk | Rel-7 | Paolo |  |
| 304 | 70.2 | Downlink Dual Carrier Stage 3 | 398d? | 2006-01-20 A | 2007-07-31 | 78% | 86.6d? | 2006-01-20 | 2007-07-31 | 398d? | 143d | finish no earlier than 2007-05-18 | G2; G1 | 3876.8h | 2491.2h | GDCDL-Stage3 | Leonardo Provvedi, Siemens AG | leonardo.provvedi@roke.co.uk | Rel-7 | Gert, Paolo |  |
| 305 | 70.3 | Downlink Dual Carrier – MS Conformance Test | 421d? | 2006-01-20 | 2007-08-31 |  |  | 2006-01-20 | 2007-08-31 | 421d? | 120d | finish no earlier than 2007-08-31 | G3 | 3368h |  | GDCDL-MStest | Leonardo Provvedi, Siemens AG | leonardo.provvedi@roke.co.uk | Rel-7 | Stoyan |  |
| 306 | 71 | Support of SIGTRAN in GERAN | 116d? | 2006-01-20 A | 2006-06-30 A | 100% |  | 2006-01-20 | 2006-06-30 | 116d? |  | finish no earlier than 2006-06-30 | GP | 928h | 928h | GSIGT | Peter Ostrup, Ericsson | peter.ostrup@ericsson.com | Rel-7 | Paolo |  |
| 307 | 72 | Packet Switched Streaming Enhancements | 261d? | 2006-06-08 A | 2007-06-07 | 50% | 130.5d? | 2006-06-08 | 2007-06-07 | 261d? | 181d | finish no earlier than 2007-06-07 | S4 | 2088h | 1044h | PSSe | Olle Franceschi (Ericsson) | olle.franceschi@ericsson.com | Rel-7 | Paolo |  |
| 308 | 73 | **Charging Management small Enhancements Rel-7** | 279d? | 2006-05-22 A | 2007-06-14 | 82% | 50.22d? | 2006-05-22 | 2007-06-14 | 279d? | 176d |  | S5 | 5952h | 4880.64h | CH7 | Orange | alain.bibas@francetelecom.com | Rel-7 | Adrian |  |
| 309 | 73.1 | Alternate Charged Party (ACP) for IMS | 279d? | 2006-05-22 A | 2007-06-14 | 80% | 55.8d? | 2006-05-22 | 2007-06-14 | 279d? | 176d | finish no earlier than 2007-06-14 | S5 | 2232h | 1785.6h | CH7-IMS-ACP | Lucent | njmazzarella@alcatel-lucent.com | Rel-7 |  |  |
| 310 | 73.2 | Align 3GPP Charging with OMA PoC Enabler Release 2.0 | 186d? | 2006-09-28 A | 2007-06-14 | 85% | 27.9d? | 2006-09-28 | 2007-06-14 | 186d? | 176d | finish no earlier than 2007-06-14 | S5 | 1488h | 1264.8h | CH7-PoC | Siemens | gerald.goermer@siemens.com | Rel-7 | Adrian |  |

Notes:
- 285: Text3: 26/03/2007
- 287: TS 24.173:IMS Multimedia telephony service and supplementary services / Text3: New TS 24.173
- 289: Moved from FS section Feb 06 / Text3: 29.163, 29.332
- 290: Moved from FS section Feb 06
- 291: Text3: 29.163
- 292: Text3: 22.101, 22.011, 23.122, 24.008, 25.304, 31.102, 45.008
- 293: Text3: 22.101, 22.011, 23.122, 24.008, 25.304, 31.102, 45.008
- 294: Text3: 23.122, 24.008, 31.102
- 295: Text3: 43.068, 43.069, 29.002
- 296: Text3: 43.068, 43.069
- 297: CT4#33: The work is 95% complited / Text3: 29.002
- 299: S2#52 CREATED. TR for Info SP-33. SP-34: S2 Report intention to discontinue TR / Text3: 23.809
- 300: S2#55 CREATED: SP-34 Approved and exception request granted until 03/07 / Text3: 23.9de
- 301: S2#52 CREATED / Text3: 23.060
- 302: Text3: 24.008, 43.055, 43.064, 44.018, 44.060, 45.001, 45.002, 45.005, 45.008, 51.010
- 303: Text3: 43.055, 43.064
- 304: Text3: 24.008, 44.018, 44.060, 45.001, 45.002, 45.005, 45.008
- 305: Text3: 51.010
- 306: Text3: 48.001, 48.006, 43.059, 49.031
- 307: Text3: 26.234, 26.244
- 308: Text3: 32.2xy
- 309: Text3: 32.240, 32.260, 32.298, 32.299
- 310: 09/2006 SA#33 WID approved / Text3: 32.240, 32.272, 32.299, 32.298

| ID | WBS | Task | Type | Duration | Start | Finish | Complete | Remaining | Baseline start | Baseline finish | Baseline duration | Total slack | Constraint | Resources | Work | Actual work | Text1 | Text4 | Text5 | Text6 | Text8 | Text12 |
| --- | --- | --- | --- | --- | --- | --- | --- | --- | --- | --- | --- | --- | --- | --- | --- | --- | --- | --- | --- | --- | --- | --- |
| 311 | 74 | **Latency Reductions** |  | 231d? | 2006-06-30 A | 2007-05-18 | 50% | 115.5d? | 2006-06-30 | 2007-05-18 | 231d? | 195d |  | GP | 5544h | 1848h | LATRED | Håkan Persson, Ericsson | Hakan.Persson@Ericsson.com | Rel-7 | Paolo |  |
| 312 | 74.1 | Improved Ack/Nack reporting |  | 231d? | 2006-06-30 A | 2007-05-18 | 50% | 115.5d? | 2006-06-30 | 2007-05-18 | 231d? | 195d | finish no earlier than 2007-05-18 | G2 | 1848h | 924h | LATRED-ACKNAR | Håkan Persson, Ericsson | Hakan.Persson@Ericsson.com | Rel-7 | Gert |  |
| 313 | 74.2 | Reduced TTI |  | 231d? | 2006-06-30 A | 2007-05-18 | 50% | 115.5d? | 2006-06-30 | 2007-05-18 | 231d? | 195d | finish no earlier than 2007-05-18 | G2 | 1848h | 924h | LATRED-REDTTI | Håkan Persson, Ericsson | Hakan.Persson@Ericsson.com | Rel-7 | Gert |  |
| 314 | 75 | PS Handover between GERAN/UTRAN mode and GAN Mode |  | 166d? | 2006-06-30 A | 2007-02-16 A | 100% |  | 2006-06-30 | 2007-02-16 | 166d? |  | finish no earlier than 2007-02-16 | G2 | 1328h | 1328h | GUGAN | John Diachina, Ericsson | John.Diachina@Ericsson.com | Rel-7 | Gert |  |
| 315 | 76 | **CSI Terminating Session handling** |  | 267d? | 2006-06-08 A | 2007-06-15 | 88% | 32.63d? | 2006-06-08 | 2007-06-15 | 267d? | 175d |  | S2 | 4728h | 4150.13h | CSItermS | Osok Song (Samsung) |  | Rel-7 | Maurice |  |
| 316 | 76.1 | Stage 2 of CStermS |  | 192d? | 2006-06-08 A | 2007-03-02 A | 100% |  | 2006-06-08 | 2007-03-02 | 192d? |  | start no earlier than 2006-06-08 | S2 | 1536h | 1536h | CSItermS | Osok Song (Samsung) |  | Rel-7 | Maurice |  |
| 317 | 76.2 | Stage 3 of CStermS |  | 132d? | 2006-12-14 A | 2007-06-15 | 70% | 39.6d? | 2006-12-14 | 2007-06-15 | 132d? | 175d | finish no earlier than 2007-06-15 | C1 | 1056h | 739.2h | CSItermS | Chen-Ho CHIN, Samsung | chenho.chin@samsung.com | Rel-7 | Andrijana |  |
| 318 | 76.3 | Deleted - duplicated with UID 340015 -Stage 3 CSI Terminating Session handling | milestone | 0d? | 2007-03-09 A | 2007-03-09 A | 100% |  | 2007-03-09 | 2007-03-09 | 0d? |  | start no earlier than 2007-03-09 | C1 |  |  | CSItermS | Chen-Ho CHIN, Samsung | chenho.chin@samsung.com | Rel-7 | Andrijana | CP-34 |
| 319 | 77 | High speed interface between the UICC and the ME |  | 311d? | 2006-09-22 A | 2007-11-30 | 5% | 295.45d? | 2006-09-22 | 2007-11-30 | 311d? | 55d | finish no earlier than 2007-11-30 | C6 | 2488h | 124.4h | HSI | Jacques Seif, Gemalto | jacques.seif@GEMALTO.COM | Rel-7 | Gaby |  |
| 320 | 78 | Interworking between the 3GPP CS domain with BICC or ISUP as signalling protocol and external SIP-I networks |  | 166d? | 2006-09-22 A | 2007-05-11 | 70% | 49.8d? | 2006-09-22 | 2007-05-11 | 166d? | 200d | finish no earlier than 2007-05-11 | C3 | 1328h | 929.6h | ExtSIPI | Thomas Belling, Siemens | thomas.belling@SIEMENS.COM | Rel-7 | Seung Don |  |
| 321 | 79 | **Higher Uplink performance for GERAN Evolution** |  | 311d? | 2006-09-08 A | 2007-11-16 | 6% | 292.18d? | 2006-09-08 | 2007-11-16 | 311d? | 65d |  | GP | 13256h | 802.15h | HUGE | E. Riddington (Nokia) and S. Eriksson (Ericsson) | eddie.riddington@nokia.com, stefan.g.eriksson@ericsson.com | Rel-7 | Paolo |  |
| 322 | 79.1 | Stage 2 of HUGE |  | 181d? | 2006-09-08 A | 2007-05-18 | 15% | 153.85d? | 2006-09-08 | 2007-05-18 | 181d? | 195d | finish no earlier than 2007-05-18 | G1 | 1448h | 217.2h | HUGE-Stage2 | E. Riddington (Nokia) and S. Eriksson (Ericsson) | eddie.riddington@nokia.com, stefan.g.eriksson@ericsson.com | Rel-7 | Paolo |  |
| 323 | 79.2 | Layer 1 Support of HUGE |  | 181d? | 2006-09-08 A | 2007-05-18 | 15% | 153.85d? | 2006-09-08 | 2007-05-18 | 181d? | 195d | finish no earlier than 2007-05-18 | G1 | 1448h | 217.2h | HUGE-Layer1 | E. Riddington (Nokia) and S. Eriksson (Ericsson) | eddie.riddington@nokia.com, stefan.g.eriksson@ericsson.com | Rel-7 | Paolo |  |
| 324 | 79.3 | Layer 2/3 Support of HUGE |  | 181d? | 2006-09-08 A | 2007-05-18 | 15% | 153.85d? | 2006-09-08 | 2007-05-18 | 181d? | 195d | finish no earlier than 2007-05-18 | G2 | 1448h | 217.2h | HUGE-Layer23 | E. Riddington (Nokia) and S. Eriksson (Ericsson) | eddie.riddington@nokia.com, stefan.g.eriksson@ericsson.com | Rel-7 | Gert |  |
| 325 | 79.4 | Performance requirements |  | 181d? | 2006-09-08 | 2007-05-18 |  |  | 2006-09-08 | 2007-05-18 | 181d? | 195d | start no earlier than 2006-09-08 | G1 | 1448h |  | HUGE-Perfreq | E. Riddington (Nokia) and S. Eriksson (Ericsson) | eddie.riddington@nokia.com, stefan.g.eriksson@ericsson.com | Rel-7 | Paolo |  |
| 326 | 79.5 | MS Conformance Test |  | 311d? | 2006-09-08 | 2007-11-16 |  |  | 2006-09-08 | 2007-11-16 | 311d? | 65d | finish no earlier than 2007-11-16 | G3 | 2488h |  | HUGE-Mstest | E. Riddington (Nokia) and S. Eriksson (Ericsson) | eddie.riddington@nokia.com, stefan.g.eriksson@ericsson.com | Rel-7 | Stoyan |  |
| 327 | 79.6 | BTS Conformance Test |  | 311d? | 2006-09-08 | 2007-11-16 |  |  | 2006-09-08 | 2007-11-16 | 311d? | 65d | start no earlier than 2006-09-08 | G1 | 2488h |  | HUGE-BTStest | E. Riddington (Nokia) and S. Eriksson (Ericsson) | eddie.riddington@nokia.com, stefan.g.eriksson@ericsson.com | Rel-7 | Paolo |  |
| 328 | 80 | Routeing of MT-SMs via the HPLMN |  | 71d? | 2006-12-01 A | 2007-03-09 A | 100% |  | 2006-12-01 | 2007-03-09 | 71d? |  | finish no earlier than 2007-03-09 | C4 | 568h | 568h | SMSviaH | Nick Russell, Vodafone UK | Nick.Russell@vodafone.com | Rel-7 | Kimmo |  |
| 329 | 81 | PDU multiplexing at Nb Interface with IP transport |  | 70d? | 2006-12-04 A | 2007-03-09 A | 100% |  | 2006-12-04 | 2007-03-09 | 70d? |  | start no earlier than 2006-12-04 | C3 | 560h | 560h | NbIPMux | Jean Rzeznik, Alcatel-Lucent | Jean.Rzeznik@alcatel-lucent.fr | Rel-7 | Seung Don |  |
| 330 | 82 | **REduced symbol Duration, Higher Order modulation and Turbo coding (RED HOT) for downlink** |  | 326d? | 2006-11-17 A | 2008-02-15 | 2% | 319.07d? | 2006-11-17 | 2008-02-15 | 326d? | 0d |  | GP | 10000h | 212.66h | REDHOT | Stefan Eriksson (Ericsson) | stefan.g.eriksson@ericsson.com | Rel-7 | Paolo |  |
| 331 | 82.1 | Stage 2 for REDHOT |  | 131d? | 2006-11-17 A | 2007-05-18 | 15% | 111.35d? | 2006-11-17 | 2007-05-18 | 131d? | 195d | finish no earlier than 2007-05-18 | G1 | 1048h | 157.2h | REDHOT-Stage2 | Stefan Eriksson (Ericsson) | stefan.g.eriksson@ericsson.com | Rel-7 | Paolo |  |
| 332 | 82.2 | Stage 3 for REDHOT |  | 206d? | 2006-11-17 | 2007-08-31 |  |  | 2006-11-17 | 2007-08-31 | 206d? | 120d | finish no earlier than 2007-08-31 | G1 | 1648h |  | REDHOT-Stage3 | Stefan Eriksson (Ericsson) | stefan.g.eriksson@ericsson.com | Rel-7 | Paolo |  |
| 333 | 82.3 | MS Conformance Tests |  | 326d? | 2006-11-17 | 2008-02-15 |  |  | 2006-11-17 | 2008-02-15 | 326d? | 0d | finish no earlier than 2008-02-15 | G3 | 2608h |  | REDHOT-MStests | Stefan Eriksson (Ericsson) | stefan.g.eriksson@ericsson.com | Rel-7 | Stoyan |  |
| 334 | 82.4 | BTS Conformance Tests |  | 261d? | 2006-11-17 | 2007-11-16 |  |  | 2006-11-17 | 2007-11-16 | 261d? | 65d | finish no earlier than 2007-11-16 | G1 | 2088h |  | REDHOT-BTStests | Stefan Eriksson (Ericsson) | stefan.g.eriksson@ericsson.com | Rel-7 | Paolo |  |
| 335 | 83 | GAN Enhancements |  | 131d? | 2006-11-17 A | 2007-05-18 | 50% | 65.5d? | 2006-11-17 | 2007-05-18 | 131d? | 195d | finish no earlier than 2007-05-18 | GP | 1048h | 524h | EGAN | Janne Linkola (T-Mobile) | janne.linkola@t-mobile.com | Rel-7 | Paolo |  |
| 336 | 84 | Mobile Termination whilst the MS is moving to another MSC |  | 60d? | 2007-03-09 A | 2007-05-31 | 15% | 51d? | 2007-03-09 | 2007-05-31 | 60d? | 186d | start no earlier than 2007-03-09 | C4 | 480h | 72h | MTmovMS | Bruno Landais Alcatel-Lucent | bruno.landais@alcatel-lucent.fr | Rel-7 |  |  |
| 337 | 85 | (Small) Technical Enhancements and Improvements for Rel-7 |  | 1886d? | 2000-01-03 | 2007-03-26 |  |  | 2000-01-03 | 2007-03-26 | 1886d? | 234d | start no earlier than 2000-01-01 | All | 15088h |  | TEI7 |  |  | Rel-7 |  |  |

Notes:
- 311: Text3: 45.001, 45.002, 45.003, 45.005, 45.010, 43.055, 43.064, 44.060, 51.010-1, 51.021
- 312: Text3: 45.001, 45.002, 45.003, 45.005, 45.010, 43.055, 43.064, 44.060, 51.010-1, 51.021
- 313: Text3: 45.001, 45.002, 45.003, 45.005, 45.010, 43.055, 43.064, 44.060, 51.010-1, 51.021
- 314: Text3: 43.318, 44.318, 43.129, 25.306, 24.008, 44.060, 25.331, 51.010
- 315: Not to be confused with FS with same name / Text3: 23.228, 23.279
- 316: Created to dissociate Stage 2 line from feature line / Text3: 23.228, 23.279
- 317: WID approved in CT#34 / Text3: 24.229, 24.279
- 318: WID approved in CT#34 / Text3: 24.229, 24.179, 24.279
- 319: Text3: 31.101, 31.102, 31.103
- 320: 08/03/2007 08:00 / Text3: new TS 29.164
- 321: Text3: 24.008, 43.055, 43.064, 44.018, 44.060, 45.001, 45.002, 45.003, 45.004, 45.005, 45.008, 45.010, 51.010, 51.021
- 322: Text3: 43.055, 43.064
- 323: Text3: 45.001, 45.002, 45.003, 45.004, 45.008
- 324: Text3: 24.008, 44.018, 44.060
- 325: Text3: 45.005
- 326: Text3: 51.010
- 327: Text3: 51.021
- 328: WID approved in CT#34 / Text3: 23.040, 29.002
- 329: 08/03/2007 08:00 / Text3: 29.414
- 330: Text3: 24.008, 43.064, 43.055, 44.018, 44.060, 45.001, 45.002, 45.003, 45.004, 45.005, 45.008, 51.010, 51.021
- 331: Text3: 43.055, 43.064
- 332: Text3: 24.008, 44.018, 44.060, 45.001, 45.002, 45.003, 45.004, 45.005, 45.008
- 333: Text3: 51.010
- 334: Text3: 51.021
- 336: Text3: 23.008, 23.012, 23.018, 23.078, 23.079, 29.002
- 337: Text3: CP-070260

| ID | WBS | Task | Type | Duration | Start | Finish | Complete | Remaining | Baseline start | Baseline finish | Baseline duration | Total slack | Constraint | Resources | Work | Actual work | Text1 | Text3 | Text4 | Text5 | Text6 | Text8 | Text12 | Text7 |
| --- | --- | --- | --- | --- | --- | --- | --- | --- | --- | --- | --- | --- | --- | --- | --- | --- | --- | --- | --- | --- | --- | --- | --- | --- |
| 338 | 86 | **Deleted - PS domain and IMS support for IMS Emergency sessions** |  | 63.69d? | 2006-06-23 A | 2006-09-21 A | 100% |  | 2006-06-23 | 2006-09-21 | 63.69d? |  |  | S2 |  |  | IMS-EMER | 23.867, TS 23.abc, 23.060, 23.002, 23.271 | Curt Wong (Nokia) | curt.c.wong@nokia.com | Rel-7 | Maurice | SP-30 |  |
| 339 | 86.1 | Deleted - IMS aspects to support IMS Emergency sessions | milestone | 0d? | 2006-06-23 A | 2006-09-21 A | 100% |  | 2006-06-23 | 2006-09-21 | 0d? |  | start no earlier than 2006-06-23 | S2 |  |  |  | 23.867, TS 23.abc, 23.060, 23.002, 23.271 | Curt Wong (Nokia) | curt.c.wong@nokia.com | Rel-7 | Maurice | SP-30 | TSG |
| 340 | 86.2 | Deleted - PS domain aspects to support IMS Emergency sessions | milestone | 0d? | 2006-06-23 A | 2006-09-21 A | 100% |  | 2006-06-23 | 2006-09-21 | 0d? |  | start no earlier than 2006-06-23 | S2 |  |  |  | 23.867, TS 23.abc, 23.060, 23.002, 23.271 | Curt Wong (Nokia) | curt.c.wong@nokia.com | Rel-7 | Maurice | SP-30 | TSG |
| 341 | 87 | Deleted - Covered by SI - Personal Network (PN) and Personal Area Network (PAN) | milestone | 0d? | 2005-12-08 A | 2005-12-20 A | 100% |  | 2005-12-08 | 2005-12-20 | 0d? |  | start no earlier than 2005-12-08 | S1 |  |  | PNPAN |  | Armin Toepfer, Vodafone | armin.toepfer@vodafone.com | Rel-7 | Mike | SP-30 |  |
| 342 | 88 | Deleted - Covered by SI - Multimedia Telephony Capabilities for IMS | milestone | 0d? | 2005-12-08 A | 2005-12-20 A | 100% |  | 2005-12-08 | 2005-12-20 | 0d? |  | start no earlier than 2005-12-08 | S1 |  |  | MITE |  | Peter Bleckert, Ericsson | peter.bleckert @ericsson.com | Rel-7 | Mike | SP-30 |  |
| 343 | 89 | Deleted - Covered by SI - Transferring of emergency Call data | milestone | 0d? | 2005-12-08 A | 2005-12-08 A | 100% |  | 2005-12-08 | 2005-12-08 | 0d? |  | start no earlier than 2005-12-08 | S1 |  |  | eCALL |  | Steve Vardy, (Motorola S.A.S) | steven.vardy@motorola.com | Rel-7 | Mike | SP-30 |  |
| 344 | 90 | Deleted - Covered by SI - MBMS Enhancements | milestone | 0d? | 2005-12-08 A | 2005-12-08 A | 100% |  | 2005-12-08 | 2005-12-08 | 0d? |  | start no earlier than 2005-12-08 | S1 |  |  | MBMSE |  | Liu Hong, China Mobile | liuhongyfw@chinamobile.com | Rel-7 | Mike | SP-30 |  |
| 345 | 91 | Rel-7 Feasibility Studies |  | 1d? | 2000-01-03 | 2000-01-03 |  |  | 2000-01-03 | 2000-01-03 | 1d? | 2119d |  | CT;RAN;SA | 8h |  |  |  |  |  | Rel-7 |  |  |  |
| 346 | 92 | **(FS on) Multimedia Telephony Capabilities for IMS** |  | 320d? | 2005-07-11 A | 2006-09-29 A | 100% |  | 2005-07-11 | 2006-09-29 | 320d? |  |  | S1 | 6089.6h | 6089.6h | MITE |  | Peter Bleckert, Ericsson | peter.bleckert @ericsson.com | Rel-7 | Mike |  |  |
| 347 | 92.1 | Study of (MITe) - IMS Multimedia Telephony Communication Enabler and supplementary services |  | 276d? | 2005-07-11 A | 2006-07-31 A | 100% |  | 2005-07-11 | 2006-07-31 | 276d? |  | start no earlier than 2005-07-11 | S1 | 2208h | 2208h |  | 22.973 | Peter Bleckert, Ericsson | peter.bleckert @ericsson.com | Rel-7 | Mike |  |  |
| 348 | 92.2 | IMS Multimedia Telephony Service |  | 173d? | 2006-02-01 A | 2006-09-29 A | 100% |  | 2006-02-01 | 2006-09-29 | 173d? |  | start no earlier than 2006-02-01 | S1 | 1384h | 1384h |  | 22.173 | Peter Bleckert, Ericsson | peter.bleckert @ericsson.com | Rel-7 | Mike |  |  |
| 349 | 93 | Study Item on IMS enhancements and optimisations for real time communication. |  | 430d? | 2005-10-10 A | 2007-06-01 | 65% | 150.5d? | 2005-10-10 | 2007-06-01 | 430d? | 185d | finish no earlier than 2007-06-01 | S2 | 3440h | 2236h | IMS-RT | 23.818 | Stephen Terrill (Ericsson) | stephen.terrill@ericsson.com | Rel-7 | Maurice |  |  |
| 350 | 94 | (FS on) Behaviour of Multi system UEs |  | 480d? | 2004-06-28 A | 2006-04-28 | 90% | 48d? | 2004-06-28 | 2006-04-28 | 480d? | 470d | start no earlier than 2004-06-28 | S1 | 3840h | 3456h | BMSU | 22.936 | D Williams (QUALCOMM) | dwilliams@qualcomm.com | Rel-7 | Michael |  | TSG |
| 351 | 95 | **FS on IMS with real time services deployment** |  | 384d? | 2004-06-28 A | 2005-12-15 | 99% | 0d? | 2004-06-28 | 2005-12-15 | 384d? | 0d |  | S1 | 8672h | 6304.24h | IRTSD |  |  |  | Rel-7 | Maurice |  | TSG |
| 352 | 95.1 | Feasibility Study on Combining CS calls and IMS sessions |  | 384d? | 2004-06-28 A | 2005-12-15 A | 100% |  | 2004-06-28 | 2005-12-15 | 384d? |  | start no earlier than 2004-06-28 | S1 | 3072h | 3072h | IRTSD-CS_IMS | 22.979, 23.899 |  |  | Rel-7 | Michael |  | TSG |
| 353 | 95.2 | TR on Stage 2 (IMS services using CS bearers) |  | 316d? | 2004-06-28 A | 2005-09-12 A | 100% |  | 2004-06-28 | 2005-09-12 | 316d? |  | finish no earlier than 2005-09-12 | S2 | 2528h | 2528h | IRTSD-IMSCS | 23.899 | Mark Watson (Nortel Networks) |  | Rel-7 | Maurice |  | TSG |
| 354 | 96 | (FS on) Terminating Session handling |  | 255d? | 2006-01-09 A | 2006-12-29 A | 100% |  | 2006-01-09 | 2006-12-29 | 255d? |  | finish no earlier than 2006-12-29 | S2 | 2040h | 2040h | CSIterm | 23.819 | Osok Song (Samsung) | osok.song@samsung.com | Rel-7 | Maurice |  |  |
| 355 | 97 | FS on Performance Evaluation of the UE behaviour in high speed trains with speeds up to 350 kmph |  | 328d? | 2005-03-15 A | 2006-06-15 A | 100% |  | 2005-03-15 | 2006-06-15 | 328d? |  | finish no earlier than 2006-06-15 | R4 | 2624h | 2624h | RANFS-HSTrains |  | Mike Vogel | Mike.vogel@vodafone.com | Rel-7 | MCC_RAN |  | TSG |
| 356 | 98 | FS on Evolved UTRA and UTRAN |  | 458d? | 2004-12-15 A | 2006-09-15 A | 100% |  | 2004-12-15 | 2006-09-15 | 458d? |  | finish no earlier than 2006-09-15 | RP | 3664h | 3664h | RANFS-Evo |  | Takehiro Nakamura (NTT DoCoMo) | nakamurata@NTTDOCOMO.CO.JP | Rel-7 | MCC_RAN |  | TSG |
| 357 | 99 | **Study on Videotelephony teleservice** |  | 231d? | 2005-03-01 A | 2006-01-17 A | 100% |  | 2005-03-01 | 2006-01-17 | 231d? |  |  | S1 | 3696h | 3696h | VidTel |  | Kurt Bischinger (T-Mobile) | kurt.bischinger@t-mobile.at | Rel-7 | Michael |  | TSG |
| 358 | 99.1 | Study on Videotelephony service requirements |  | 231d? | 2005-03-01 A | 2006-01-17 A | 100% |  | 2005-03-01 | 2006-01-17 | 231d? |  | start no earlier than 2005-03-01 | S1 | 1848h | 1848h |  | 22.903 | Kurt Bischinger (T-Mobile) | kurt.bischinger@t-mobile.at | Rel-7 | Michael |  | TSG |
| 359 | 100 | **Study of Network Selection Principles** |  | 193d? | 2005-03-15 A | 2005-12-08 | 99% | 0d? | 2005-03-15 | 2005-12-08 | 193d? | 0d |  | S1 | 3088h | 2658.02h | NetSel |  | Chris Friel (O2) | chris.friel@o2.com | Rel-7 | Michael |  | TSG |
| 360 | 100.1 | Review of Network Selection Principles |  | 193d? | 2005-03-15 A | 2005-12-08 A | 100% |  | 2005-03-15 | 2005-12-08 | 193d? |  | finish no earlier than 2005-12-08 | S1 | 1544h | 1544h |  | 22.811 | Chris Friel (O2) | chris.friel@o2.com | Rel-7 | Michael |  | TSG |
| 361 | 101 | FS on Continuous connectivity for packet data users |  | 132d? | 2005-03-15 A | 2005-09-15 A | 100% |  | 2005-03-15 | 2005-09-15 | 132d? |  | finish no earlier than 2005-09-15 | R1 | 1056h | 1056h | RANFS-cont-packet |  | Joerg Gustrau | joerg.gustrau@siemens.com | Rel-7 | MCC_RAN |  | TSG |
| 362 | 102 | FS on UTRA Tower Mounted Amplifier (FDD) |  | 195d? | 2005-06-15 A | 2006-03-14 A | 100% |  | 2005-06-15 | 2006-03-14 | 195d? |  | finish no earlier than 2006-03-15 | R4 | 1560h | 1560h | RANFS-TMA |  | Klas Sjerling | Klas.Sjerling@ericsson.com | Rel-7 | MCC_RAN |  | TSG |
| 363 | 103 | (FS on) Multimedia Priority Service |  | 851d? | 2003-03-28 A | 2006-06-30 A | 100% |  | 2003-03-28 | 2006-06-30 | 851d? |  | finish no earlier than 2005-12-16 | S1 | 6808h | 6808h | PRIOR-MM | 22.953 | Jim Garrahan (Telcordia) | jgarraha@telcordia.com | Rel-7 | Michael |  |  |
| 364 | 104 | (FS on) Transferring of emergency Call data |  | 190d? | 2005-07-11 A | 2006-03-31 A | 100% |  | 2005-07-11 | 2006-03-31 | 190d? |  | finish no earlier than 2005-12-08 | S1 | 1520h | 1520h | eCALL | 22.967 | Steve Vardy, (Motorola S.A.S) | steven.vardy@motorola.com | Rel-7 | Mike |  |  |
| 365 | 105 | FS on Routeing of MT-SMs via the HPLMN |  | 301d? | 2005-10-07 A | 2006-12-01 A | 100% |  | 2005-10-07 | 2006-12-01 | 301d? |  | finish no earlier than 2006-12-01 | C4 | 2408h | 2408h | SMS7 | 23.840 | Nick Russell, Vodafone UK | Nick.Russell@vodafone.com | Rel-7 | Kimmo |  |  |
| 366 | 106 | FS on Improvement of the Multimedia Broadcast Multicast Service (MBMS) in UTRAN |  | 262d? | 2005-12-15 A | 2006-12-15 A | 100% |  | 2005-12-15 | 2006-12-15 | 262d? |  | finish no earlier than 2006-12-15 | R2 | 2096h | 2096h | RANFS-MBMSImp |  | YoungDae Lee, LG | leego@lge.com | Rel-7 | MCC_RAN |  |  |
| 367 | 107 | FS on Performance Improvements in Small Cells using HSDPA/EDCH |  | 131d? | 2005-12-15 A | 2006-06-15 A | 100% |  | 2005-12-15 | 2006-06-15 | 131d? |  | finish no earlier than 2006-06-15 | R4 | 1048h | 1048h | SMALLCELLS |  | Marc Grant, Cingular | marc.grant@cingular.com | Rel-7 | MCC_RAN |  |  |
| 368 | 108 | FS on Further Improved Performance Requirements for UMTS/HSDPA UE (FDD) |  | 383d? | 2005-12-15 A | 2007-06-04 | 60% | 153.2d? | 2005-12-15 | 2007-06-04 | 383d? | 184d | finish no earlier than 2007-06-04 | R4 | 3064h | 1838.4h | RANFS-IC |  | Marc Grant, Cingular | marc.grant@cingular.com | Rel-7 | MCC_RAN |  |  |
| 369 | 109 | FS on the TCAPsec Gateway concept |  | 96d? | 2005-10-28 A | 2006-03-10 A | 100% |  | 2005-10-28 | 2006-03-10 | 96d? |  | finish no earlier than 2006-03-10 | C4 | 768h | 768h | SEC7-TCAP | 29.800 | Ulrich Wiehe, Siemens | Ulrich.wiehe@gksag.de | Rel-7 | Kimmo |  |  |
| 370 | 110 | Study of Customised Alerting Tone (CAT) Requirements |  | 191d? | 2005-10-07 A | 2006-06-30 | 65% | 66.85d? | 2005-10-07 | 2006-06-30 | 191d? | 425d | start no earlier than 2005-10-07 | S1 | 1528h | 993.2h | CAT | 22.982 | Feng Lingjuan, China Mobile | fenglingjuan@chinamobile.com | Rel-7 | Michael |  |  |
| 371 | 111 | SI on Scope of future FDD HSPA Evolution |  | 319d? | 2006-03-15 A | 2007-06-04 | 75% | 79.75d? | 2006-03-15 | 2007-06-04 | 319d? | 184d | finish no earlier than 2007-06-04 | RP | 2552h | 1914h | RANFS-HSPAEvo |  | Don Zelmer | don.zelmer@cingular.com | Rel-7 | MCC_RAN |  |  |

Notes:
- 338: Approved at SP#29
- 339: Approved at SP#29
- 340: Approved at SP#29
- 346: Moved from FS section Feb 06
- 349: Approved at SP#29. To be shown as feature - END Sept 06
- 350: The WID still calls it a BB, not a Feature.
- 354: S2#52: Split into Study and Specification phases.
- 363: Moved from Rel6, "FS on" added by MCC to distinguish from actual feature
- 365: Previously known as "Study of a SMS Centre for MT SMS"
- 366: Completed at RP#34 as RP-060692
- 369: Study WI...
- 370: Awaiting MCC SA3 input; No input from SA3 at this time

| ID | WBS | Task | Type | Duration | Start | Finish | Complete | Remaining | Baseline start | Baseline finish | Baseline duration | Total slack | Constraint | Resources | Work | Actual work | Text1 | Text4 | Text5 | Text6 | Text7 | Text8 | Text3 | Text12 |
| --- | --- | --- | --- | --- | --- | --- | --- | --- | --- | --- | --- | --- | --- | --- | --- | --- | --- | --- | --- | --- | --- | --- | --- | --- |
| 372 | 112 | **OAM&P Studies** |  | 400d? | 2005-09-02 A | 2007-03-15 | 99% | 0d? | 2005-09-02 | 2007-03-15 | 400d? | 0d |  | S5 | 14880h | 14368h | OAM-Study | Toche | Christian.Toche@huawei.com | Rel-7 | TSG | Adrian |  |  |
| 373 | 112.1 | Study of SOAP/HTTP IRP Solution Sets |  | 330d? | 2005-09-02 A | 2006-12-07 A | 100% |  | 2005-09-02 | 2006-12-07 | 330d? |  | finish no earlier than 2006-12-07 | S5 | 2640h | 2640h |  | Nortel |  | Rel-7 |  |  | TR 32.809 | SP-32 |
| 374 | 112.2 | Study of Itf-N Implementation Conformance Statement (ICS) template |  | 400d? | 2005-09-02 A | 2007-03-15 A | 100% |  | 2005-09-02 | 2007-03-15 | 400d? |  | finish no earlier than 2007-03-15 | S5 | 3200h | 3200h |  | China Mobile |  | Rel-7 |  |  | TR 32.812 | SP-32 |
| 375 | 112.3 | Study of IRP Information Model |  | 400d? | 2005-09-02 A | 2007-03-15 A | 100% |  | 2005-09-02 | 2007-03-15 | 400d? |  | finish no earlier than 2007-03-15 | S5 | 3200h | 3200h |  | Motorola |  | Rel-7 |  |  | TR 32.810 | SP-32 |
| 376 | 112.4 | Stopped - Study on IRP usage scenarios |  | 330d? | 2005-09-02 A | 2006-12-07 A | 100% |  | 2005-09-02 | 2006-12-07 | 330d? |  | finish no earlier than 2006-12-07 | S5 | 2640h | 2640h |  | Lucent |  | Rel-7 |  |  | new TR 32.8xy | SP-32 |
| 377 | 112.5 | **Deleted - Network Infrastructure Management** |  | 0d? | 2006-12-15 A | 2006-12-15 A | 100% |  | 2006-12-15 | 2006-12-15 | 0d? |  |  | S5 |  |  | OAM7-NIM |  |  | Rel-7 |  |  |  | SP-32 |
| 378 | 112.5.1 | Delete - was duplicated - Study on SA5 MTOSI XML Harmonization | milestone | 0d? | 2006-12-15 A | 2006-12-15 A | 100% |  | 2006-12-15 | 2006-12-15 | 0d? |  | start no earlier than 2006-12-15 | S5 |  |  | OAM7-NIM-XML | Nortel |  | Rel-7 |  |  | new TR 32.8xy | SP-30 |
| 379 | 113 | FS of using M2PA in 3GPP network |  | 318d? | 2006-03-22 A | 2007-06-08 | 60% | 127.2d? | 2006-03-22 | 2007-06-08 | 318d? | 180d | finish no earlier than 2007-06-08 | C4 | 2544h | 1526.4h | FS-M2PA | Zhao Yuyi | zhaoyuyi@chinamobile.com | Rel-7 |  | Kimmo |  |  |
| 380 | 114 | (FS on) Enhancement of E2E QoS |  | 336.4d? | 2004-06-28 A | 2005-12-01 A | 100% |  | 2004-06-28 | 2005-12-01 | 336.4d? |  | finish no earlier than 2005-12-01 | S2 | 2691.2h | 2691.2h | QoS7 |  |  | Rel-7 | TSG | Maurice | 23.802 |  |
| 381 | 115 | FS WID on Bandwidth Saving at Nb Interface with IP transport |  | 261d? | 2006-03-10 A | 2007-03-09 A | 100% |  | 2006-03-10 | 2007-03-09 | 261d? |  | finish no earlier than 2007-03-09 | C3 | 2088h | 2088h | BSNbIP | Thomas BELLING(Siemens) | thomas.belling@siemens.com | Rel-7 |  | Seung Don | new TR 29.814 |  |
| 382 | 116 | **(FS on) 3GPP System Architecture Evolution** |  | 736d? | 2004-12-03 A | 2007-09-28 | 73% | 196.37d? | 2004-12-03 | 2007-09-28 | 736d? | 100d |  | S2 | 11864h | 8698.68h | SAE |  |  | Rel-7 | TSG |  |  |  |
| 383 | 116.1 | Stage 2 Interim conclusion for RAN Work to start |  | 211d? | 2004-12-03 A | 2005-09-23 A | 100% |  | 2004-12-03 | 2005-09-23 | 211d? |  | finish no earlier than 2005-09-23 | S2 | 1688h | 1688h |  |  |  | Rel-7 |  |  | 23.882 |  |
| 384 | 116.2 | Stage 2 Feasibility study on 3GPP architectural development |  | 450d? | 2006-01-09 A | 2007-09-28 | 71% | 130.5d? | 2006-01-09 | 2007-09-28 | 450d? | 100d | finish no earlier than 2007-09-28 | S2 | 3600h | 2556h |  | Chris Pudney |  | Rel-7 |  | Maurice | 23.882 |  |
| 385 | 116.3 | Security study for Inter-access mobility between non 3GPP and 3GPP system |  | 86d? | 2006-02-03 A | 2006-06-02 | 20% | 68.8d? | 2006-02-03 | 2006-06-02 | 86d? | 445d | start no earlier than 2006-02-03 | S3 | 688h | 137.6h | SAE-Sec | Dajiang Zhang (Nokia) | dajiang.zhang@NOKIA.COM | Rel-7 |  |  | 23.882, 33.821, 33.922 |  |
| 386 | 116.4 | Deleted - Duplicateed with 32087 - Stage 2 Feasibility study on 3GPP architectural development | milestone | 0d? | 2006-09-27 A | 2006-09-27 A | 100% |  | 2006-09-27 | 2006-09-27 | 0d? |  | start no earlier than 2006-09-27 | S2 |  |  |  |  |  | Rel-7 |  |  | 23.882 | SP-32 |
| 387 | 117 | **FS WID on Support of (G)MSC-S - (G)MSC-S Nc Interface based on the SIP-I protocol** |  | 275d? | 2006-05-15 A | 2007-06-01 | 52% | 132.86d? | 2006-05-15 | 2007-06-01 | 275d? | 185d |  | C4 | 5640h | 2915.09h | NcSIP | David Hutton, Vodafone Group | david.hutton@vodafone.com | Rel-7 |  | Kimmo | 29.802 |  |
| 388 | 117.1 | CT4 aspects of NcSIP |  | 275d? | 2006-05-15 A | 2007-06-01 | 47% | 145.75d? | 2006-05-15 | 2007-06-01 | 275d? | 185d | finish no earlier than 2007-06-01 | C4 | 2200h | 1034h |  |  |  | Rel-7 |  |  | 29.802 |  |
| 389 | 117.2 | CT3 aspects of NcSIP |  | 155d? | 2006-05-15 A | 2006-12-15 | 60% | 62d? | 2006-05-15 | 2006-12-15 | 155d? | 305d | start no earlier than 2006-05-15 | C3 | 1240h | 744h |  | Ragnar Huslende, Ericsson | ragnar.huslende@ericsson.com | Rel-7 |  |  |  |  |
| 390 | 118 | (FS on) Transferring of emergency call data – in-band modem solution |  | 131d? | 2006-12-07 A | 2007-06-07 | 10% | 117.9d? | 2006-12-07 | 2007-06-07 | 131d? | 181d | finish no earlier than 2007-06-07 | S4 | 1048h | 104.8h | eCALLIBMS | Leon Hong, Airbiquity | lhong@airbiquity.com | Rel-7 |  | Paolo | 26.9xy |  |
| 391 | 119 | **Study on Dynamically reconfiguring a FDD UE receiver to reduce power consumption when desired Quality of Service is met** |  | 181d? | 2006-09-25 A | 2007-06-04 | 90% | 18.1d? | 2006-09-25 | 2007-06-04 | 181d? | 184d |  | RP | 4344h | 3909.6h | FSUEPow | Chris Callender, Nokia | Chris.callender@nokia.com | Rel-7 |  | MCC_RAN | 25.xxx |  |
| 392 | 119.1 | RAN2 aspects of FSUEPow |  | 181d? | 2006-09-25 A | 2007-06-04 | 90% | 18.1d? | 2006-09-25 | 2007-06-04 | 181d? | 184d | finish no earlier than 2007-06-04 | R2 | 1448h | 1303.2h | FSUEPow | Tiina Koskinen (Nokia) | tiina.s.koskinen@nokia.com | Rel-7 |  | MCC_RAN |  |  |
| 393 | 119.2 | RAN4 aspects of FSUEPow |  | 181d? | 2006-09-25 A | 2007-06-04 | 90% | 18.1d? | 2006-09-25 | 2007-06-04 | 181d? | 184d | finish no earlier than 2007-06-04 | R4 | 1448h | 1303.2h | FSUEPow | Tiina Koskinen (Nokia) | tiina.s.koskinen@nokia.com | Rel-7 |  | MCC_RAN |  |  |
| 394 | 120 | deleted - covered by UID33027 - IMS security extensions | milestone | 0d? | 2005-12-08 A | 2005-12-08 A | 100% |  | 2005-12-08 | 2005-12-08 | 0d? |  | start no earlier than 2005-12-08 | S3 |  |  | IMS-SE | Bengt Sahlin, Ericsson | Bengt.Sahlin@ericsson.com | Rel-7 |  | Mike |  | SP-30 |
| 395 | 121 | Deleted - covered by 32108 - Study of work on an LCS architecture for I-WLAN | milestone | 0d? | 2006-12-08 A | 2006-12-08 A | 100% |  | 2006-12-08 | 2006-12-08 | 0d? |  | start no earlier than 2006-12-08 | S2 |  |  |  | Donghee Shim (LG Electronics Inc.) | dhshim@lge.com ; phede@lge.com | Rel-7 |  | Maurice |  | SP-33 |

Notes:
- 380: Moved to a FS as SA32 (in line with slides)
- 381: Moved to FS at CT32 (in line with slides)
- 383: RAN work started
- 384: Some items left SR VCC, Local Breakout, Network Access Selection
- 387: Study WI
- 395: S2#52: Entry created

| ID | WBS | Task | Type | Duration | Start | Finish | Complete | Baseline start | Baseline finish | Baseline duration | Constraint | Resources | Text1 | Text6 | Text12 | Text3 | Text4 | Text5 | Text7 | Text8 |
| --- | --- | --- | --- | --- | --- | --- | --- | --- | --- | --- | --- | --- | --- | --- | --- | --- | --- | --- | --- | --- |
| 396 | 122 | **Deleted: FS on applicability of GALILEO for LCS** |  | 0d? | 2005-06-30 A | 2005-06-30 A | 100% | 2005-06-30 | 2005-06-30 | 0d? |  | S2 | Galileo | Rel-7 | SP-25 |  |  |  |  |  |
| 397 | 122.1 | Deleted - TR on Stage 2 | milestone | 0d? | 2005-06-30 A | 2005-06-30 A | 100% | 2005-06-30 | 2005-06-30 | 0d? | finish no earlier than 2005-06-30 | S2 |  | Rel-7 | SP-25 |  |  |  |  |  |
| 398 | 122.2 | deleted - GERAN review of the TR | milestone | 0d? | 2005-06-30 A | 2005-06-30 A | 100% | 2005-06-30 | 2005-06-30 | 0d? | start no earlier than 2005-06-30 | GP |  | Rel-7 | SP-26 |  |  |  |  |  |
| 399 | 16.7 | **Deleted - IMS Local services** |  | 0d? | 2006-01-06 A | 2006-01-06 A | 100% | 2006-01-06 | 2006-01-06 | 0d? |  | S2 | IMSLocal | Rel-7 | SP-28 | 23.228 |  |  |  |  |
| 400 | 16.7.1 | Deleted - Stage 2 | milestone | 0d | 2006-01-06 A | 2006-01-06 A | 100% | 2006-01-06 | 2006-01-06 | 0d | start no earlier than 2006-01-06 | S2 |  | Rel-7 | SP-26 |  |  |  |  |  |
| 401 | 123.2 | Delete - Stage 3 for IMS Local services | milestone | 0d? | 2006-01-06 A | 2006-01-06 A | 100% | 2006-01-06 | 2006-01-06 | 0d? | finish no earlier than 2006-01-06 | C1 |  | Rel-7 | SP-25 |  | Keith Drage, Lucent | drage@lucent.com |  |  |
| 402 | 124 | Deleted - IMS Phase 3 | milestone | 0d? | 2006-01-06 A | 2006-01-06 A | 100% | 2006-01-06 | 2006-01-06 | 0d? | start no earlier than 2006-01-06 | S2 |  | Rel-7 | SP-25 |  |  |  |  |  |
| 403 | 125 | Deleted - Improvements of Radio Interface | milestone | 0d? | 2004-09-15 A | 2004-09-15 A | 100% | 2004-09-15 | 2004-09-15 | 0d? | start no earlier than 2004-09-15 | RP | RInImp | Rel-7 | SP-24 |  |  | Rel-7 | TSG | Claude |
| 404 | 126 | Deleted: Generic User Profile Phase 2 | milestone | 0d | 2005-08-08 A | 2006-06-30 A | 100% | 2005-08-08 | 2006-06-30 | 0d |  | C4 |  | Rel-7 | SP-27 |  |  |  |  | Gaby |
| 405 | 30.4 | Deleted - Stage 3 - Common objects | milestone | 0d | 2005-08-08 A | 2006-06-30 A | 100% | 2005-08-08 | 2006-06-30 | 0d | finish no earlier than 2006-06-30 | C4 |  | Rel-7 | SP-27 | 24.241 |  |  | TSG | Gaby |
| 406 | 128 | Delete was duplicated- Study of Customised Alerting Tone (CAT) Requirements | milestone | 0d? | 2006-06-30 A | 2006-06-30 A | 100% | 2006-06-30 | 2006-06-30 | 0d? | start no earlier than 2006-06-30 | S1 | CAT | Rel-7 | SP-31 |  |  |  |  |  |
| 407 | 129 | Delete - was duplicated - Facilitating Machine to Machine Communication in GSM and UMTS (M2M) | milestone | 0d? | 2006-06-30 A | 2006-06-30 A | 100% | 2006-06-30 | 2006-06-30 | 0d? | start no earlier than 2006-06-30 | S1 | M2M | Rel-7 | SP-32 | 22.868 | Juergen Merkel, Siemens AG |  |  | Michael |
| 408 | 130 | Deleted - FS of enhanced support of Video Telephony | milestone | 0d? | 2006-06-30 A | 2006-06-30 A | 100% | 2006-06-30 | 2006-06-30 | 0d? | start no earlier than 2006-06-30 | GP | VIDGER | Rel-7 | SP-32 |  | Stefan Eriksson, Ericsson | stefan.g.eriksson@ericsson.com | TSG | Paolo |

Notes:
- 400: DAB - Not yet required in SA2 as it exists in previous releases
- 403: Stage 2 description of Interim conclusion
- 404: Created at TSG#27 by A. Sultan because of the move to Rel-7 of "Common Objects".
- 405: No progress in CN4#26. This have to be moved to Rel-7. It was deleted from WID
- 406: Awaiting MCC SA3 input
- 408: FS CLOSED at G#28 (no input)
